# ESP schedule

Schedule from MS Project, 2005-12-14 to 2006-12-04, A marks actual dates.
MBARI

## Calendars

- Standard: Mon-Fri 08:00-12:00, 13:00-17:00; Sat-Sun off.

## Resources

| Resource |
| --- |
| Scott |
| Gene |
| Brent |
| Chris S. |
| Chris P. |
| Roman |
| Mark Brown |
| Science Team |
| Bob |

## Schedule

| ID | WBS | Task | Type | Duration | Start | Finish | Complete | Remaining | Baseline start | Baseline finish | Baseline duration | Total slack | Constraint | Resources | Work | Actual work |
| --- | --- | --- | --- | --- | --- | --- | --- | --- | --- | --- | --- | --- | --- | --- | --- | --- |
| 1 | 1 | **GiGi core** |  | 55d? | 2005-12-14 A | 2006-02-28 | 14% | 47.19d? | 2005-12-14 | 2006-01-04 | 16d? | 199d |  |  | 828h | 36h |
| 2 | 1.1 | Final instrument modifications |  | 1d? | 2006-01-04 | 2006-01-04 |  |  | 2006-01-04 | 2006-01-04 | 1d? | 238d |  |  |  |  |
| 4 | 1.2 | **Refit system valves to Cheminert valves** |  | 40d? | 2005-12-14 A | 2006-02-07 | 41% | 23.68d? | 2005-12-14 | 2006-01-04 | 16d? | 214d |  |  | 148h | 36h |
| 5 | 1.2.1 | Order new valves |  | 0.5d | 2005-12-14 A | 2005-12-14 A | 100% |  | 2005-12-14 | 2005-12-14 | 0.5d |  | start no earlier than 2005-12-14 | Scott | 4h | 4h |
| 6 | 1.2.2 | Split cost of valves | milestone | 0d | 2006-01-04 | 2006-01-04 |  |  |  |  |  | 239d |  |  |  |  |
| 7 | 1.2.3 | Valves arrive | milestone | 0d | 2006-01-04 | 2006-01-04 |  |  | 2006-01-04 | 2006-01-04 | 1d? | 239d |  |  |  |  |
| 8 | 1.2.4 | **Valve bracket redesign** |  | 2d? | 2006-01-04 A | 2006-01-05 A | 100% |  | 2006-01-04 | 2006-01-04 | 1d? |  |  |  | 32h | 32h |
| 9 | 1.2.4.1 | **Design** |  | 2d? | 2006-01-04 A | 2006-01-05 A | 100% |  | 2006-01-04 | 2006-01-04 | 1d? |  |  |  | 24h | 24h |
| 10 | 1.2.4.1.1 | EE |  | 1.43d? | 2006-01-04 A | 2006-01-05 A | 100% |  | 2006-01-04 | 2006-01-04 | 1d? |  |  | Scott [70%] | 8h | 8h |
| 11 | 1.2.4.1.2 | ME |  | 2d? | 2006-01-04 A | 2006-01-05 A | 100% |  | 2006-01-04 | 2006-01-04 | 1d? |  |  | Gene [50%] | 8h | 8h |
| 12 | 1.2.4.1.3 | SE |  | 1.43d? | 2006-01-04 A | 2006-01-05 A | 100% |  | 2006-01-04 | 2006-01-04 | 1d? |  |  | Brent [70%] | 8h | 8h |
| 13 | 1.2.4.2 | **Part procurment** |  | 2d? | 2006-01-04 A | 2006-01-05 A | 100% |  | 2006-01-04 | 2006-01-04 | 1d? |  |  |  | 8h | 8h |
| 14 | 1.2.4.2.1 | ME Tech |  | 1d? | 2006-01-04 A | 2006-01-04 A | 100% |  |  |  |  |  |  |  |  |  |
| 15 | 1.2.4.2.2 | ME |  | 2d? | 2006-01-04 A | 2006-01-05 A | 100% |  | 2006-01-04 | 2006-01-04 | 1d? |  |  | Gene [50%] | 8h | 8h |
| 16 | 1.2.4.3 | **fabrication** |  | 1d? | 2006-01-04 A | 2006-01-04 A | 100% |  | 2006-01-04 | 2006-01-04 | 1d? |  |  |  |  |  |
| 17 | 1.2.4.3.1 | METech |  | 1d? | 2006-01-04 A | 2006-01-04 A | 100% |  |  |  |  |  |  |  |  |  |
| 18 | 1.2.4.3.2 | ME |  | 1d? | 2006-01-04 A | 2006-01-04 A | 100% |  |  |  |  |  |  |  |  |  |
| 19 | 1.2.4.3.3 | EE |  | 1d? | 2006-01-04 A | 2006-01-04 A | 100% |  |  |  |  |  |  |  |  |  |
| 20 | 1.2.4.4 | **Assembly** |  | 1d? | 2006-01-04 A | 2006-01-04 A | 100% |  | 2006-01-04 | 2006-01-04 | 1d? |  |  |  |  |  |
| 21 | 1.2.4.4.1 | ME Tech |  | 1d? | 2006-01-04 A | 2006-01-04 A | 100% |  |  |  |  |  |  |  |  |  |
| 22 | 1.2.5 | **Valve placement in instrument** |  | 1d? | 2006-01-04 A | 2006-01-04 | 90% | 0.1d? | 2006-01-04 | 2006-01-04 | 1d? | 238d |  |  |  |  |
| 23 | 1.2.5.1 | Physical modelling for valve placement |  | 1d? | 2006-01-04 A | 2006-01-04 A | 100% |  | 2006-01-04 | 2006-01-04 | 1d? |  |  |  |  |  |
| 24 | 1.2.5.2 | **Instrument modifications** |  | 1d? | 2006-01-04 A | 2006-01-04 A | 100% |  | 2006-01-04 | 2006-01-04 | 1d? |  |  |  |  |  |
| 25 | 1.2.5.2.1 | **Fabrication** |  | 1d? | 2006-01-04 A | 2006-01-04 A | 100% |  | 2006-01-04 | 2006-01-04 | 1d? |  |  |  |  |  |
| 26 | 1.2.5.2.1.1 | ME tech |  | 1d? | 2006-01-04 A | 2006-01-04 A | 100% |  |  |  |  |  |  |  |  |  |
| 27 | 1.2.5.2.1.2 | ME |  | 1d? | 2006-01-04 A | 2006-01-04 A | 100% |  |  |  |  |  |  |  |  |  |
| 28 | 1.2.5.2.1.3 | shop |  | 1d? | 2006-01-04 A | 2006-01-04 A | 100% |  |  |  |  |  |  |  |  |  |

Notes:
- 5: Placed order with VICI with two PO's / PO-0512876 4,6,8 using C25-618x vavles / PO-0512876 for custom 4 port loop C22-6184-MBA / Custom was $base+25 and +1wk
- 7: Standard valves arrived ealry than planned 12/21/05 / Waiting for custom

| ID | WBS | Task | Duration | Start | Finish | Complete | Baseline start | Baseline finish | Baseline duration | Total slack | Constraint | Resources | Work |
| --- | --- | --- | --- | --- | --- | --- | --- | --- | --- | --- | --- | --- | --- |
| 29 | 1.2.5.2.2 | **assembly** | 1d? | 2006-01-04 A | 2006-01-04 A | 100% | 2006-01-04 | 2006-01-04 | 1d? |  |  |  |  |
| 30 | 1.2.5.2.2.1 | ME tech | 1d? | 2006-01-04 A | 2006-01-04 A | 100% |  |  |  |  |  |  |  |
| 31 | 1.2.5.2.2.2 | ME | 1d? | 2006-01-04 A | 2006-01-04 A | 100% |  |  |  |  |  |  |  |
| 32 | 1.2.5.2.2.3 | shop | 1d? | 2006-01-04 A | 2006-01-04 A | 100% |  |  |  |  |  |  |  |
| 33 | 1.2.5.2.2.4 | EE | 1d? | 2006-01-04 A | 2006-01-04 A | 100% |  |  |  |  |  |  |  |
| 34 | 1.2.5.2.2.5 | SE | 1d? | 2006-01-04 A | 2006-01-04 A | 100% |  |  |  |  |  |  |  |
| 35 | 1.2.5.3 | **Testing** | 1d? | 2006-01-04 | 2006-01-04 |  | 2006-01-04 | 2006-01-04 | 1d? | 238d |  |  |  |
| 36 | 1.2.5.3.1 | EE | 1d? | 2006-01-04 | 2006-01-04 |  |  |  |  | 238d |  |  |  |
| 37 | 1.2.6 | Protocol redevelopment | 10d | 2006-01-25 | 2006-02-07 |  | 2006-01-04 | 2006-01-04 | 1d? | 214d | start no earlier than 2006-01-25 | Science Team | 80h |
| 38 | 1.2.7 | **Refit completion** | 20d? | 2006-01-04 | 2006-01-31 |  | 2006-01-04 | 2006-01-04 | 1d? | 219d |  |  | 32h |
| 39 | 1.2.7.1 | Model and drawing update - MB | 20d? | 2006-01-04 | 2006-01-31 |  | 2006-01-04 | 2006-01-04 | 1d? | 219d |  | Mark Brown [20%] | 32h |
| 41 | 1.3 | **modify bulkhead valves - eliminate solenoid** | 1d? | 2006-01-04 | 2006-01-04 |  | 2006-01-04 | 2006-01-04 | 1d? | 238d |  |  | 280h |
| 42 | 1.3.1 | **design** | 1d? | 2006-01-04 | 2006-01-04 |  | 2006-01-04 | 2006-01-04 | 1d? | 238d |  |  | 112h |
| 43 | 1.3.1.1 | EE | 1d? | 2006-01-04 | 2006-01-04 |  |  |  |  | 238d |  |  | 40h |
| 44 | 1.3.1.2 | ME | 1d? | 2006-01-04 | 2006-01-04 |  |  |  |  | 238d |  |  | 56h |
| 45 | 1.3.1.3 | SE | 1d? | 2006-01-04 | 2006-01-04 |  |  |  |  | 238d |  |  | 16h |
| 46 | 1.3.2 | **Fabricate** | 1d? | 2006-01-04 | 2006-01-04 |  |  |  |  | 238d |  |  | 72h |
| 47 | 1.3.2.1 | EE | 1d? | 2006-01-04 | 2006-01-04 |  |  |  |  | 238d |  |  | 16h |
| 48 | 1.3.2.2 | ME | 1d? | 2006-01-04 | 2006-01-04 |  |  |  |  | 238d |  |  | 8h |
| 49 | 1.3.2.3 | ME Tech | 1d? | 2006-01-04 | 2006-01-04 |  |  |  |  | 238d |  |  | 16h |
| 50 | 1.3.2.4 | EE Tech | 1d? | 2006-01-04 | 2006-01-04 |  |  |  |  | 238d |  |  | 8h |
| 51 | 1.3.2.5 | Shop | 1d? | 2006-01-04 | 2006-01-04 |  | 2006-01-04 | 2006-01-04 | 1d? | 238d |  |  | 24h |
| 52 | 1.3.3 | **test and integrate** | 1d? | 2006-01-04 | 2006-01-04 |  | 2006-01-04 | 2006-01-04 | 1d? | 238d |  |  | 96h |
| 53 | 1.3.3.1 | EE | 1d? | 2006-01-04 | 2006-01-04 |  |  |  |  | 238d |  |  | 40h |
| 54 | 1.3.3.2 | ME | 1d? | 2006-01-04 | 2006-01-04 |  |  |  |  | 238d |  |  | 16h |
| 55 | 1.3.3.3 | SE | 1d? | 2006-01-04 | 2006-01-04 |  |  |  |  | 238d |  |  | 16h |
| 56 | 1.3.3.4 | ME Tech | 1d? | 2006-01-04 | 2006-01-04 |  |  |  |  | 238d |  |  | 24h |

| ID | WBS | Task | Duration | Start | Finish | Baseline start | Baseline finish | Baseline duration | Total slack | Free slack | Constraint | Resources | Work |
| --- | --- | --- | --- | --- | --- | --- | --- | --- | --- | --- | --- | --- | --- |
| 58 | 1.4 | **Software** | 40d | 2006-01-04 | 2006-02-28 |  |  |  | 187d |  |  |  | 400h |
| 59 | 1.4.1 | **Contextual Sensors** | 30d | 2006-01-04 | 2006-02-14 |  |  |  | 209d |  |  |  | 280h |
| 60 | 1.4.1.1 | SE | 30d | 2006-01-04 | 2006-02-14 |  |  |  | 209d |  |  | Brent [16.7%] | 40h |
| 61 | 1.4.1.2 | External SE | 30d | 2006-01-04 | 2006-02-14 |  |  |  | 209d |  |  | Bob | 240h |
| 62 | 1.4.2 | Power cycling | 25d | 2006-01-25 | 2006-02-28 |  |  |  | 181d | 0d | start no earlier than 2006-01-25 | Brent [60%] | 120h |
| 64 | 2 | **shutter on sample intake port (50m depth max)** | 1d? | 2006-01-04 | 2006-01-04 | 2006-01-04 | 2006-01-04 | 1d? | 238d |  |  |  | 328h |
| 65 | 2.1 | **design** | 1d? | 2006-01-04 | 2006-01-04 | 2006-01-04 | 2006-01-04 | 1d? | 238d |  |  |  | 120h |
| 66 | 2.1.1 | EE | 1d? | 2006-01-04 | 2006-01-04 |  |  |  | 238d |  |  |  | 40h |
| 67 | 2.1.2 | ME | 1d? | 2006-01-04 | 2006-01-04 |  |  |  | 238d |  |  |  | 64h |
| 68 | 2.1.3 | SE | 1d? | 2006-01-04 | 2006-01-04 |  |  |  | 238d |  |  |  | 16h |
| 69 | 2.2 | **Fabricate** | 1d? | 2006-01-04 | 2006-01-04 |  |  |  | 238d |  |  |  | 112h |
| 70 | 2.2.1 | EE | 1d? | 2006-01-04 | 2006-01-04 |  |  |  | 238d |  |  |  | 16h |
| 71 | 2.2.2 | ME | 1d? | 2006-01-04 | 2006-01-04 |  |  |  | 238d |  |  |  | 8h |
| 72 | 2.2.3 | ME Tech | 1d? | 2006-01-04 | 2006-01-04 |  |  |  | 238d |  |  |  | 16h |
| 73 | 2.2.4 | EE Tech | 1d? | 2006-01-04 | 2006-01-04 |  |  |  | 238d |  |  |  | 8h |
| 74 | 2.2.5 | Shop | 1d? | 2006-01-04 | 2006-01-04 | 2006-01-04 | 2006-01-04 | 1d? | 238d |  |  |  | 64h |
| 75 | 2.3 | **test and integrate** | 1d? | 2006-01-04 | 2006-01-04 | 2006-01-04 | 2006-01-04 | 1d? | 238d |  |  |  | 96h |
| 76 | 2.3.1 | EE | 1d? | 2006-01-04 | 2006-01-04 |  |  |  | 238d |  |  |  | 40h |
| 77 | 2.3.2 | ME | 1d? | 2006-01-04 | 2006-01-04 |  |  |  | 238d |  |  |  | 16h |
| 78 | 2.3.3 | SE | 1d? | 2006-01-04 | 2006-01-04 |  |  |  | 238d |  |  |  | 16h |
| 79 | 2.3.4 | ME Tech | 1d? | 2006-01-04 | 2006-01-04 |  |  |  | 238d |  |  |  | 24h |
| 81 | 3 | **Software** | 1d? | 2006-01-04 | 2006-01-04 | 2006-01-04 | 2006-01-04 | 1d? | 238d |  |  |  | 280h |
| 82 | 3.1 | GUI | 1d? | 2006-01-04 | 2006-01-04 | 2006-01-04 | 2006-01-04 | 1d? | 238d |  |  |  |  |
| 83 | 3.2 | annimator | 1d? | 2006-01-04 | 2006-01-04 | 2006-01-04 | 2006-01-04 | 1d? | 238d |  |  |  | 280h |

| ID | WBS | Task | Duration | Start | Finish | Predecessors | Baseline start | Baseline finish | Baseline duration | Total slack | Free slack | Constraint | Resources | Work |
| --- | --- | --- | --- | --- | --- | --- | --- | --- | --- | --- | --- | --- | --- | --- |
| 85 | 4 | **Finish surface surface water housing for GiGi** | 35d | 2006-01-25 | 2006-03-14 |  | 2006-01-04 | 2006-01-04 | 1d? | 189d |  |  |  | 24h |
| 86 | 4.1 | **Pressure housing for GiGi - surface water - 50m** | 35d | 2006-01-25 | 2006-03-14 |  | 2006-01-04 | 2006-01-04 | 1d? | 189d |  |  |  | 24h |
| 87 | 4.1.1 | **Design** | 8d | 2006-01-25 | 2006-02-03 |  | 2006-01-04 | 2006-01-04 | 1d? | 189d | 0d |  |  | 8h |
| 88 | 4.1.1.1 | ME | 8d | 2006-01-25 | 2006-02-03 |  |  |  |  | 189d |  | start no earlier than 2006-01-25 | Gene [12.5%] | 8h |
| 89 | 4.1.2 | **assembly** | 25d | 2006-02-06 | 2006-03-10 | 87 | 2006-01-04 | 2006-01-04 | 1d? | 189d | 0d |  |  | 8h |
| 90 | 4.1.2.1 | Outside fab | 25d | 2006-02-06 | 2006-03-10 |  |  |  |  | 189d |  |  |  |  |
| 91 | 4.1.2.2 | ME tech | 2d | 2006-02-06 | 2006-02-07 |  |  |  |  | 212d |  |  |  | 8h |
| 92 | 4.1.3 | **Pressure test** | 2d | 2006-03-13 | 2006-03-14 | 89 | 2006-01-04 | 2006-01-04 | 1d? | 189d |  |  |  | 8h |
| 93 | 4.1.3.1 | ME tech | 2d | 2006-03-13 | 2006-03-14 |  |  |  |  | 189d |  |  |  | 8h |
| 94 | 5 | **Shallow water deployments** | 149d? | 2006-03-08 | 2006-10-02 |  | 2006-01-04 | 2006-03-08 | 45d? | 45d |  |  |  | 480h |
| 95 | 5.1 | **Deployment 1** | 14d? | 2006-03-08 | 2006-03-27 |  | 2006-01-04 | 2006-03-08 | 45d? | 180d |  |  |  | 52h |
| 96 | 5.1.1 | MOB | 1d | 2006-03-08 | 2006-03-09 | 100SF | 2006-01-04 | 2006-01-04 | 1d? | 192d | 0d | start no earlier than 2006-03-08 |  |  |
| 97 | 5.1.2 | **MOB resources** | 1d? | 2006-03-08 | 2006-03-08 | 96SS |  |  |  | 193d |  |  |  | 12h |
| 98 | 5.1.2.1 | EE | 1d? | 2006-03-08 | 2006-03-08 |  |  |  |  | 193d |  |  |  | 8h |
| 99 | 5.1.2.2 | ME | 1d? | 2006-03-08 | 2006-03-08 |  |  |  |  | 193d |  |  |  | 4h |
| 100 | 5.1.3 | Deployment | 13d | 2006-03-09 | 2006-03-27 |  | 2006-03-08 | 2006-03-08 | 0d | 180d | 0d | start no earlier than 2006-03-09 |  |  |
| 101 | 5.1.4 | **Deployment resources** | 13d? | 2006-03-09 | 2006-03-27 |  |  |  |  | 180d |  |  |  | 40h |
| 102 | 5.1.4.1 | **Deploy** | 1d? | 2006-03-09 | 2006-03-09 | 100SS |  |  |  | 192d |  |  |  | 20h |
| 103 | 5.1.4.1.1 | EE | 1d? | 2006-03-09 | 2006-03-09 |  |  |  |  | 192d |  |  |  | 12h |
| 104 | 5.1.4.1.2 | ME | 1d? | 2006-03-09 | 2006-03-09 |  |  |  |  | 192d |  |  |  | 8h |
| 105 | 5.1.4.2 | **Recover** | 2d | 2006-03-24 | 2006-03-27 |  |  |  |  | 180d |  |  |  | 20h |
| 106 | 5.1.4.2.1 | EE | 2d | 2006-03-24 | 2006-03-27 | 100FF |  |  |  | 180d |  |  |  | 12h |
| 107 | 5.1.4.2.2 | ME | 2d | 2006-03-24 | 2006-03-27 | 100FF |  |  |  | 180d |  |  |  | 8h |
| 108 | 5.2 | **Deployment 2** | 16d? | 2006-04-03 | 2006-04-24 |  | 2006-01-04 | 2006-03-08 | 45d? | 160d |  |  |  | 36h |
| 109 | 5.2.1 | MOB | 1d | 2006-04-03 | 2006-04-03 | 113SS | 2006-01-04 | 2006-01-04 | 1d? | 175d | 0d | start no earlier than 2006-03-08 |  |  |

| ID | WBS | Task | Duration | Start | Finish | Predecessors | Baseline start | Baseline finish | Baseline duration | Total slack | Free slack | Constraint | Work |
| --- | --- | --- | --- | --- | --- | --- | --- | --- | --- | --- | --- | --- | --- |
| 110 | 5.2.2 | **MOB resources** | 1d? | 2006-04-03 | 2006-04-03 | 109SS |  |  |  | 175d |  |  | 12h |
| 111 | 5.2.2.1 | EE | 1d? | 2006-04-03 | 2006-04-03 |  |  |  |  | 175d |  |  | 8h |
| 112 | 5.2.2.2 | ME | 1d? | 2006-04-03 | 2006-04-03 |  |  |  |  | 175d |  |  | 4h |
| 113 | 5.2.3 | Deployment | 16d | 2006-04-03 | 2006-04-24 |  | 2006-03-08 | 2006-03-08 | 0d | 160d | 0d | finish no earlier than 2006-04-24 |  |
| 114 | 5.2.4 | **Deployment resources** | 16d? | 2006-04-03 | 2006-04-24 |  |  |  |  | 160d |  |  | 24h |
| 115 | 5.2.4.1 | **Deploy** | 1d? | 2006-04-03 | 2006-04-03 | 113SS |  |  |  | 175d |  |  | 16h |
| 116 | 5.2.4.1.1 | EE | 1d? | 2006-04-03 | 2006-04-03 |  |  |  |  | 175d |  |  | 8h |
| 117 | 5.2.4.1.2 | ME | 1d? | 2006-04-03 | 2006-04-03 |  |  |  |  | 175d |  |  | 8h |
| 118 | 5.2.4.2 | **Recover** | 2d | 2006-04-21 | 2006-04-24 |  |  |  |  | 160d |  |  | 8h |
| 119 | 5.2.4.2.1 | EE | 2d | 2006-04-21 | 2006-04-24 | 113FF |  |  |  | 160d |  |  | 8h |
| 120 | 5.2.4.2.2 | ME | 2d | 2006-04-21 | 2006-04-24 | 113FF |  |  |  | 160d |  |  |  |
| 121 | 5.3 | **Deployment 3** | 10d? | 2006-05-01 | 2006-05-12 |  | 2006-01-04 | 2006-03-08 | 45d? | 146d |  |  | 24h |
| 122 | 5.3.1 | MOB | 1d | 2006-05-01 | 2006-05-01 | 125SS | 2006-01-04 | 2006-01-04 | 1d? | 155d | 0d | start no earlier than 2006-03-08 |  |
| 123 | 5.3.2 | **MOB resources** | 1d? | 2006-05-01 | 2006-05-01 | 122SS |  |  |  | 155d |  |  | 8h |
| 124 | 5.3.2.1 | EE | 1d? | 2006-05-01 | 2006-05-01 |  |  |  |  | 155d |  |  | 8h |
| 125 | 5.3.3 | Deployment | 10d | 2006-05-01 | 2006-05-12 |  | 2006-03-08 | 2006-03-08 | 0d | 146d | 0d | start no earlier than 2006-05-01 |  |
| 126 | 5.3.4 | **Deployment resources** | 10d? | 2006-05-01 | 2006-05-12 |  |  |  |  | 146d |  |  | 16h |
| 127 | 5.3.4.1 | **Deploy** | 1d? | 2006-05-01 | 2006-05-01 | 125SS |  |  |  | 155d |  |  | 8h |
| 128 | 5.3.4.1.1 | EE | 1d? | 2006-05-01 | 2006-05-01 |  |  |  |  | 155d |  |  | 8h |
| 129 | 5.3.4.2 | **Recover** | 2d | 2006-05-11 | 2006-05-12 |  |  |  |  | 146d |  |  | 8h |
| 130 | 5.3.4.2.1 | EE | 2d | 2006-05-11 | 2006-05-12 | 125FF |  |  |  | 146d |  |  | 8h |
| 131 | 5.4 | **Deployment 4** | 20d? | 2006-05-30 | 2006-06-26 |  | 2006-01-04 | 2006-03-08 | 45d? | 115d |  |  | 24h |
| 132 | 5.4.1 | MOB | 1d | 2006-05-30 | 2006-05-30 | 135SS | 2006-01-04 | 2006-01-04 | 1d? | 134d | 0d | start no earlier than 2006-03-08 |  |
| 133 | 5.4.2 | **MOB resources** | 1d? | 2006-05-30 | 2006-05-30 | 132SS |  |  |  | 134d |  |  | 8h |
| 134 | 5.4.2.1 | EE | 1d? | 2006-05-30 | 2006-05-30 |  |  |  |  | 134d |  |  | 8h |
| 135 | 5.4.3 | Deployment | 20d | 2006-05-30 | 2006-06-26 |  | 2006-03-08 | 2006-03-08 | 0d | 115d | 0d | start no earlier than 2006-05-30 |  |

| ID | WBS | Task | Duration | Start | Finish | Predecessors | Baseline start | Baseline finish | Baseline duration | Total slack | Free slack | Constraint | Work |
| --- | --- | --- | --- | --- | --- | --- | --- | --- | --- | --- | --- | --- | --- |
| 136 | 5.4.4 | **Deployment resources** | 20d? | 2006-05-30 | 2006-06-26 |  |  |  |  | 115d |  |  | 16h |
| 137 | 5.4.4.1 | **Deploy** | 1d? | 2006-05-30 | 2006-05-30 | 135SS |  |  |  | 134d |  |  | 8h |
| 138 | 5.4.4.1.1 | EE | 1d? | 2006-05-30 | 2006-05-30 |  |  |  |  | 134d |  |  | 8h |
| 139 | 5.4.4.2 | **Recover** | 2d | 2006-06-23 | 2006-06-26 |  |  |  |  | 115d |  |  | 8h |
| 140 | 5.4.4.2.1 | EE | 2d | 2006-06-23 | 2006-06-26 | 135FF |  |  |  | 115d |  |  | 8h |
| 141 | 5.5 | **Deployment 5** | 14d? | 2006-07-05 | 2006-07-24 |  | 2006-01-04 | 2006-03-08 | 45d? | 95d |  |  | 24h |
| 142 | 5.5.1 | MOB | 1d | 2006-07-05 | 2006-07-05 | 145SS | 2006-01-04 | 2006-01-04 | 1d? | 108d | 0d | start no earlier than 2006-03-08 |  |
| 143 | 5.5.2 | **MOB resources** | 1d? | 2006-07-05 | 2006-07-05 | 142SS |  |  |  | 108d |  |  | 8h |
| 144 | 5.5.2.1 | EE | 1d? | 2006-07-05 | 2006-07-05 |  |  |  |  | 108d |  |  | 8h |
| 145 | 5.5.3 | Deployment | 14d | 2006-07-05 | 2006-07-24 |  | 2006-03-08 | 2006-03-08 | 0d | 95d | 0d | start no earlier than 2006-07-05 |  |
| 146 | 5.5.4 | **Deployment resources** | 14d? | 2006-07-05 | 2006-07-24 |  |  |  |  | 95d |  |  | 16h |
| 147 | 5.5.4.1 | **Deploy** | 1d? | 2006-07-05 | 2006-07-05 | 145SS |  |  |  | 108d |  |  | 8h |
| 148 | 5.5.4.1.1 | EE | 1d? | 2006-07-05 | 2006-07-05 |  |  |  |  | 108d |  |  | 8h |
| 149 | 5.5.4.2 | **Recover** | 2d | 2006-07-21 | 2006-07-24 |  |  |  |  | 95d |  |  | 8h |
| 150 | 5.5.4.2.1 | EE | 2d | 2006-07-21 | 2006-07-24 | 145FF |  |  |  | 95d |  |  | 8h |
| 151 | 5.6 | **Deployment 6** | 17d? | 2006-09-08 | 2006-10-02 |  | 2006-01-04 | 2006-03-08 | 45d? | 45d |  |  | 24h |
| 152 | 5.6.1 | MOB | 1d | 2006-09-08 | 2006-09-08 | 155SS | 2006-01-04 | 2006-01-04 | 1d? | 61d | 0d | start no earlier than 2006-03-08 |  |
| 153 | 5.6.2 | **MOB resources** | 1d? | 2006-09-08 | 2006-09-08 | 152SS |  |  |  | 61d |  |  | 8h |
| 154 | 5.6.2.1 | EE | 1d? | 2006-09-08 | 2006-09-08 |  |  |  |  | 61d |  |  | 8h |
| 155 | 5.6.3 | Deployment | 17d | 2006-09-08 | 2006-10-02 |  | 2006-03-08 | 2006-03-08 | 0d | 45d | 0d | start no earlier than 2006-09-08 |  |
| 156 | 5.6.4 | **Deployment resources** | 17d? | 2006-09-08 | 2006-10-02 |  |  |  |  | 45d |  |  | 16h |
| 157 | 5.6.4.1 | **Deploy** | 1d? | 2006-09-08 | 2006-09-08 | 155SS |  |  |  | 61d |  |  | 8h |
| 158 | 5.6.4.1.1 | EE | 1d? | 2006-09-08 | 2006-09-08 |  |  |  |  | 61d |  |  | 8h |
| 159 | 5.6.4.2 | **Recover** | 2d | 2006-09-29 | 2006-10-02 |  |  |  |  | 45d |  |  | 8h |
| 160 | 5.6.4.2.1 | EE | 2d | 2006-09-29 | 2006-10-02 | 155FF |  |  |  | 45d |  |  | 8h |

| ID | WBS | Task | Duration | Start | Finish | Predecessors | Complete | Remaining | Baseline start | Baseline finish | Baseline duration | Total slack | Free slack | Constraint | Resources | Work |
| --- | --- | --- | --- | --- | --- | --- | --- | --- | --- | --- | --- | --- | --- | --- | --- | --- |
| 161 | 5.7 | **Deployment contingency** | 2d | 2006-09-29 | 2006-10-02 |  |  |  |  |  |  | 45d |  |  |  | 296h |
| 162 | 5.7.1 | EE | 2d | 2006-09-29 | 2006-10-02 | 96SS |  |  |  |  |  | 45d |  | finish no earlier than 2006-10-02 |  | 48h |
| 163 | 5.7.2 | ME | 2d | 2006-09-29 | 2006-10-02 | 96SS |  |  |  |  |  | 45d |  | finish no earlier than 2006-10-02 |  | 64h |
| 164 | 5.7.3 | SE | 2d | 2006-09-29 | 2006-10-02 | 96SS |  |  |  |  |  | 45d |  | finish no earlier than 2006-10-02 |  | 120h |
| 165 | 5.7.4 | ME Tech | 2d | 2006-09-29 | 2006-10-02 | 96SS |  |  |  |  |  | 45d |  | finish no earlier than 2006-10-02 |  | 40h |
| 166 | 5.7.5 | EE Tech | 2d | 2006-09-29 | 2006-10-02 | 96SS |  |  |  |  |  | 45d |  | finish no earlier than 2006-10-02 |  | 24h |
| 168 | 6 | **Tech xfer** | 239d? | 2006-01-04 | 2006-12-04 |  |  |  | 2006-01-04 | 2006-01-04 | 1d? | 0d |  |  |  | 1040h |
| 169 | 6.1 | Build 3 copies using exisiting design and spec, based on GiGi working | 130d | 2006-06-05 | 2006-12-01 |  |  |  | 2006-01-04 | 2006-01-04 | 1d? | 1d | 0d | start no earlier than 2006-06-05 |  |  |
| 170 | 6.2 | **Copy Resources** | 1d? | 2006-06-05 | 2006-06-05 |  |  |  |  |  |  | 130d |  |  |  | 760h |
| 171 | 6.2.1 | EE | 1d? | 2006-06-05 | 2006-06-05 | 169SS |  |  |  |  |  | 130d |  |  |  | 160h |
| 172 | 6.2.2 | ME | 1d? | 2006-06-05 | 2006-06-05 | 169SS |  |  |  |  |  | 130d |  |  |  | 40h |
| 173 | 6.2.3 | SE | 1d? | 2006-06-05 | 2006-06-05 | 169SS |  |  |  |  |  | 130d |  |  |  | 40h |
| 174 | 6.2.4 | ME Tech | 1d? | 2006-06-05 | 2006-06-05 | 169SS |  |  |  |  |  | 130d |  |  |  | 320h |
| 175 | 6.2.5 | EE Tech | 1d? | 2006-06-05 | 2006-06-05 | 169SS |  |  |  |  |  | 130d |  |  |  | 160h |
| 176 | 6.2.6 | Shop | 1d? | 2006-06-05 | 2006-06-05 | 169SS |  |  |  |  |  | 130d |  |  |  | 40h |
| 177 | 6.3 | initial user workshop - prep for demo deployments in 07; joint proposals | 1d? | 2006-01-04 | 2006-01-04 |  |  |  | 2006-01-04 | 2006-01-04 | 1d? | 238d |  |  |  |  |
| 178 | 6.4 | **workshop Resources** | 1d? | 2006-12-04 | 2006-12-04 |  |  |  |  |  |  | 0d |  |  |  | 280h |
| 179 | 6.4.1 | EE | 1d? | 2006-12-04 | 2006-12-04 | 177SS |  |  |  |  |  | 0d |  | start no earlier than 2006-12-04 |  | 80h |
| 180 | 6.4.2 | ME | 1d? | 2006-12-04 | 2006-12-04 | 177SS |  |  |  |  |  | 0d |  | start no earlier than 2006-12-04 |  | 80h |
| 181 | 6.4.3 | SE | 1d? | 2006-12-04 | 2006-12-04 | 177SS |  |  |  |  |  | 0d |  | start no earlier than 2006-12-04 |  | 120h |
| 183 | 7 | **Deep water GiGI** | 239d? | 2006-01-04 A | 2006-12-04 |  | 1% | 237.65d? | 2006-01-04 | 2006-01-04 | 1d? | 0d |  |  |  | 888h |
| 184 | 7.1 | **D-ESP system testing** | 68d? | 2006-01-04 A | 2006-04-07 |  | 1% | 67.35d? | 2006-01-04 | 2006-01-04 | 1d? | 171d |  |  |  | 328h |
| 185 | 7.1.1 | 2G ESP valves and syringes in test fixture - 4C target | 1d? | 2006-01-04 A | 2006-01-04 |  | 75% | 0.25d? | 2006-01-04 | 2006-01-04 | 1d? | 238d |  |  |  |  |
| 186 | 7.1.2 | **DWSM Benchtop I&T** | 50d | 2006-01-04 | 2006-03-14 |  |  |  |  |  |  | 171d | 0d |  |  | 152h |
| 187 | 7.1.2.1 | EE | 6d | 2006-01-04 | 2006-01-11 |  |  |  |  |  |  | 215d |  |  | Scott [50%] | 24h |
| 188 | 7.1.2.2 | ME | 9d | 2006-01-04 | 2006-01-16 |  |  |  |  |  |  | 212d |  |  | Mark Brown [33.3%] | 24h |
| 189 | 7.1.2.3 | SE | 10d | 2006-03-01 | 2006-03-14 | 62 |  |  |  |  |  | 171d |  |  | Brent | 80h |
| 190 | 7.1.2.4 | Shop | 10d | 2006-01-04 | 2006-01-17 |  |  |  |  |  |  | 211d |  |  |  | 24h |

Notes:
- 187: Analog sum and difference / New external cable to include pressures

| ID | WBS | Task | Duration | Start | Finish | Predecessors | Total slack | Free slack | Resources | Work |
| --- | --- | --- | --- | --- | --- | --- | --- | --- | --- | --- |
| 191 | 7.1.3 | **DWSM Coldroom testing** | 4d | 2006-03-15 | 2006-03-20 | 186 | 171d | 0d |  | 40h |
| 192 | 7.1.3.1 | EE | 4d | 2006-03-15 | 2006-03-20 |  | 171d |  | Scott [50%] | 16h |
| 193 | 7.1.3.2 | ME | 4d | 2006-03-15 | 2006-03-20 |  | 171d |  |  | 16h |
| 194 | 7.1.3.3 | SE | 2d | 2006-03-15 | 2006-03-16 |  | 173d |  | Brent [50%] | 8h |
| 195 | 7.1.4 | **DWSM ROV test** | 9d | 2006-03-21 | 2006-03-31 | 191 | 171d | 0d |  | 64h |
| 196 | 7.1.4.1 | EE | 9d | 2006-03-21 | 2006-03-31 |  | 171d |  | Scott [33.3%] | 24h |
| 197 | 7.1.4.2 | ME | 6d | 2006-03-21 | 2006-03-28 |  | 174d |  |  | 24h |
| 198 | 7.1.4.3 | SE | 4d | 2006-03-21 | 2006-03-24 |  | 176d |  | Brent [50%] | 16h |
| 199 | 7.1.5 | **D-ESP Benchtop I&T** | 1d? | 2006-04-03 | 2006-04-03 | 195 | 171d | 0d |  | 16h |
| 200 | 7.1.5.1 | EE | 1d? | 2006-04-03 | 2006-04-03 |  | 171d |  | Scott | 8h |
| 201 | 7.1.5.2 | ME | 1d? | 2006-04-03 | 2006-04-03 |  | 171d |  |  |  |
| 202 | 7.1.5.3 | SE | 1d? | 2006-04-03 | 2006-04-03 |  | 171d |  | Brent | 8h |
| 203 | 7.1.6 | **D-ESP Coldroom testing** | 1d? | 2006-04-04 | 2006-04-04 | 199 | 171d | 0d |  | 16h |
| 204 | 7.1.6.1 | EE | 1d? | 2006-04-04 | 2006-04-04 |  | 171d |  | Scott | 8h |
| 205 | 7.1.6.2 | ME | 1d? | 2006-04-04 | 2006-04-04 |  | 171d |  |  |  |
| 206 | 7.1.6.3 | SE | 1d? | 2006-04-04 | 2006-04-04 |  | 171d |  | Brent | 8h |
| 207 | 7.1.7 | **D-ESP Tank Test** | 1d? | 2006-04-05 | 2006-04-05 | 203 | 171d | 0d |  | 16h |
| 208 | 7.1.7.1 | EE | 1d? | 2006-04-05 | 2006-04-05 |  | 171d |  | Scott | 8h |
| 209 | 7.1.7.2 | ME | 1d? | 2006-04-05 | 2006-04-05 |  | 171d |  |  |  |
| 210 | 7.1.7.3 | SE | 1d? | 2006-04-05 | 2006-04-05 |  | 171d |  | Brent | 8h |
| 211 | 7.1.8 | **D-ESP ROV test** | 2d? | 2006-04-06 | 2006-04-07 | 207 | 171d |  |  | 24h |
| 212 | 7.1.8.1 | EE | 2d? | 2006-04-06 | 2006-04-07 |  | 171d |  | Scott | 16h |
| 213 | 7.1.8.2 | ME | 1d? | 2006-04-06 | 2006-04-06 |  | 172d |  |  |  |
| 214 | 7.1.8.3 | SE | 1d? | 2006-04-06 | 2006-04-06 |  | 172d |  | Brent | 8h |

| ID | WBS | Task | Duration | Start | Finish | Baseline start | Baseline finish | Baseline duration | Total slack | Constraint | Work |
| --- | --- | --- | --- | --- | --- | --- | --- | --- | --- | --- | --- |
| 215 | 7.2 | **Deploy D-ESP on ROV - 2, 1day dives (2mobs)** | 187d? | 2006-01-04 | 2006-09-21 | 2006-01-04 | 2006-01-04 | 1d? | 52d |  | 80h |
| 216 | 7.2.1 | **Deployment 1** | 176d? | 2006-01-04 | 2006-09-06 |  |  |  | 63d |  | 40h |
| 217 | 7.2.1.1 | MOB | 1d? | 2006-01-04 | 2006-01-04 |  |  |  | 238d |  |  |
| 218 | 7.2.1.2 | **MOB resources** | 176d? | 2006-01-04 | 2006-09-06 |  |  |  | 63d |  | 24h |
| 219 | 7.2.1.2.1 | EE | 1d? | 2006-01-04 | 2006-01-04 |  |  |  | 238d |  | 8h |
| 220 | 7.2.1.2.2 | ME | 1d? | 2006-01-04 | 2006-01-04 |  |  |  | 238d |  | 8h |
| 221 | 7.2.1.2.3 | ME Tech | 1d? | 2006-01-04 | 2006-01-04 |  |  |  | 238d |  | 8h |
| 222 | 7.2.1.2.4 | Deployment | 1d? | 2006-09-06 | 2006-09-06 |  |  |  | 63d | start no earlier than 2006-09-06 |  |
| 223 | 7.2.1.3 | **Deployment** | 1d? | 2006-01-04 | 2006-01-04 |  |  |  | 238d |  | 16h |
| 224 | 7.2.1.3.1 | EE | 1d? | 2006-01-04 | 2006-01-04 |  |  |  | 238d |  | 8h |
| 225 | 7.2.1.3.2 | ME | 1d? | 2006-01-04 | 2006-01-04 |  |  |  | 238d |  | 8h |
| 226 | 7.2.2 | **Deployment 2** | 187d? | 2006-01-04 | 2006-09-21 |  |  |  | 52d |  | 40h |
| 227 | 7.2.2.1 | MOB | 1d? | 2006-01-04 | 2006-01-04 |  |  |  | 238d |  |  |
| 228 | 7.2.2.2 | **MOB resources** | 187d? | 2006-01-04 | 2006-09-21 |  |  |  | 52d |  | 24h |
| 229 | 7.2.2.2.1 | EE | 1d? | 2006-01-04 | 2006-01-04 |  |  |  | 238d |  | 8h |
| 230 | 7.2.2.2.2 | ME | 1d? | 2006-01-04 | 2006-01-04 |  |  |  | 238d |  | 8h |
| 231 | 7.2.2.2.3 | ME Tech | 1d? | 2006-01-04 | 2006-01-04 |  |  |  | 238d |  | 8h |
| 232 | 7.2.2.2.4 | Deplyment | 1d? | 2006-09-21 | 2006-09-21 |  |  |  | 52d | start no earlier than 2006-09-21 |  |
| 233 | 7.2.2.3 | **Deployment** | 1d? | 2006-01-04 | 2006-01-04 |  |  |  | 238d |  | 16h |
| 234 | 7.2.2.3.1 | EE | 1d? | 2006-01-04 | 2006-01-04 |  |  |  | 238d |  | 8h |
| 235 | 7.2.2.3.2 | ME | 1d? | 2006-01-04 | 2006-01-04 |  |  |  | 238d |  | 8h |
| 236 | 7.3 | **MARS interface** | 1d? | 2006-01-04 | 2006-01-04 | 2006-01-04 | 2006-01-04 | 1d? | 238d |  | 344h |
| 237 | 7.3.1 | **Power Supply and Communication** | 1d? | 2006-01-04 | 2006-01-04 | 2006-01-04 | 2006-01-04 | 1d? | 238d |  | 240h |
| 238 | 7.3.1.1 | EE | 1d? | 2006-01-04 | 2006-01-04 |  |  |  | 238d |  | 160h |
| 239 | 7.3.1.2 | ME | 1d? | 2006-01-04 | 2006-01-04 |  |  |  | 238d |  | 16h |
| 240 | 7.3.1.3 | SE | 1d? | 2006-01-04 | 2006-01-04 |  |  |  | 238d |  | 24h |
| 241 | 7.3.1.4 | ME Tech | 1d? | 2006-01-04 | 2006-01-04 |  |  |  | 238d |  | 40h |

| ID | WBS | Task | Duration | Start | Finish | Baseline start | Baseline finish | Baseline duration | Total slack | Constraint | Work |
| --- | --- | --- | --- | --- | --- | --- | --- | --- | --- | --- | --- |
| 242 | 7.3.2 | **deployment structure** | 1d? | 2006-01-04 | 2006-01-04 | 2006-01-04 | 2006-01-04 | 1d? | 238d |  | 104h |
| 243 | 7.3.2.1 | ME | 1d? | 2006-01-04 | 2006-01-04 |  |  |  | 238d |  | 24h |
| 244 | 7.3.2.2 | ME Tech | 1d? | 2006-01-04 | 2006-01-04 |  |  |  | 238d |  | 40h |
| 245 | 7.3.2.3 | Shop | 1d? | 2006-01-04 | 2006-01-04 |  |  |  | 238d |  | 40h |
| 246 | 7.4 | **MARS deployment** | 239d? | 2006-01-04 | 2006-12-04 | 2006-01-04 | 2006-01-04 | 1d? | 0d |  | 136h |
| 247 | 7.4.1 | MOB | 1d? | 2006-11-03 | 2006-11-03 |  |  |  | 21d | start no earlier than 2006-11-03 |  |
| 248 | 7.4.2 | **MOB** | 239d? | 2006-01-04 | 2006-12-04 | 2006-01-04 | 2006-01-04 | 1d? | 0d |  | 72h |
| 249 | 7.4.2.1 | EE | 1d? | 2006-01-04 | 2006-01-04 |  |  |  | 238d |  | 24h |
| 250 | 7.4.2.2 | ME | 1d? | 2006-01-04 | 2006-01-04 |  |  |  | 238d |  | 8h |
| 251 | 7.4.2.3 | SE | 1d? | 2006-01-04 | 2006-01-04 |  |  |  | 238d |  |  |
| 252 | 7.4.2.4 | ME Tech | 1d? | 2006-01-04 | 2006-01-04 |  |  |  | 238d |  | 40h |
| 253 | 7.4.2.5 | EE Tech | 1d? | 2006-01-04 | 2006-01-04 |  |  |  | 238d |  |  |
| 254 | 7.4.2.6 | Shop | 1d? | 2006-01-04 | 2006-01-04 |  |  |  | 238d |  |  |
| 255 | 7.4.2.7 | Deployment | 21d? | 2006-11-06 | 2006-12-04 |  |  |  | 0d | finish no earlier than 2006-12-04 |  |
| 256 | 7.4.3 | **contingency/support** | 1d? | 2006-01-04 | 2006-01-04 | 2006-01-04 | 2006-01-04 | 1d? | 238d |  | 64h |
| 257 | 7.4.3.1 | EE | 1d? | 2006-01-04 | 2006-01-04 |  |  |  | 238d |  | 8h |
| 258 | 7.4.3.2 | ME | 1d? | 2006-01-04 | 2006-01-04 |  |  |  | 238d |  | 8h |
| 259 | 7.4.3.3 | SE | 1d? | 2006-01-04 | 2006-01-04 |  |  |  | 238d |  | 24h |
| 260 | 7.4.3.4 | ME Tech | 1d? | 2006-01-04 | 2006-01-04 |  |  |  | 238d |  | 24h |
| 261 | 7.4.3.5 | EE Tech | 1d? | 2006-01-04 | 2006-01-04 |  |  |  | 238d |  |  |
| 262 | 7.4.3.6 | Shop | 1d? | 2006-01-04 | 2006-01-04 |  |  |  | 238d |  |  |
| 264 | 8 | **NASA ASTEP** | 1d? | 2006-01-04 | 2006-01-04 | 2006-01-04 | 2006-01-04 | 1d? | 238d |  | 2480h |
| 265 | 8.1 | **system spec project start** | 1d? | 2006-01-04 | 2006-01-04 | 2006-01-04 | 2006-01-04 | 1d? | 238d |  | 280h |
| 266 | 8.1.1 | Sci | 1d? | 2006-01-04 | 2006-01-04 |  |  |  | 238d |  |  |
| 267 | 8.1.2 | Sci Tech | 1d? | 2006-01-04 | 2006-01-04 |  |  |  | 238d |  |  |
| 268 | 8.1.3 | EE | 1d? | 2006-01-04 | 2006-01-04 |  |  |  | 238d |  | 80h |
| 269 | 8.1.4 | ME | 1d? | 2006-01-04 | 2006-01-04 |  |  |  | 238d |  | 160h |
| 270 | 8.1.5 | SE | 1d? | 2006-01-04 | 2006-01-04 |  |  |  | 238d |  | 40h |

| ID | WBS | Task | Duration | Start | Finish | Baseline start | Baseline finish | Baseline duration | Total slack | Work |
| --- | --- | --- | --- | --- | --- | --- | --- | --- | --- | --- |
| 271 | 8.2 | **analytical mod incorp (assumes LLNL subcontract funded - PCR)** | 1d? | 2006-01-04 | 2006-01-04 | 2006-01-04 | 2006-01-04 | 1d? | 238d | 360h |
| 272 | 8.2.1 | Sci | 1d? | 2006-01-04 | 2006-01-04 |  |  |  | 238d |  |
| 273 | 8.2.2 | Sci Tech | 1d? | 2006-01-04 | 2006-01-04 |  |  |  | 238d |  |
| 274 | 8.2.3 | EE | 1d? | 2006-01-04 | 2006-01-04 |  |  |  | 238d | 80h |
| 275 | 8.2.4 | ME | 1d? | 2006-01-04 | 2006-01-04 |  |  |  | 238d | 80h |
| 276 | 8.2.5 | SE | 1d? | 2006-01-04 | 2006-01-04 |  |  |  | 238d | 200h |
| 277 | 8.3 | **ISUS context sensor incorp** | 1d? | 2006-01-04 | 2006-01-04 | 2006-01-04 | 2006-01-04 | 1d? | 238d | 120h |
| 278 | 8.3.1 | Sci | 1d? | 2006-01-04 | 2006-01-04 |  |  |  | 238d |  |
| 279 | 8.3.2 | Sci Tech | 1d? | 2006-01-04 | 2006-01-04 |  |  |  | 238d |  |
| 280 | 8.3.3 | EE | 1d? | 2006-01-04 | 2006-01-04 |  |  |  | 238d | 16h |
| 281 | 8.3.4 | ME | 1d? | 2006-01-04 | 2006-01-04 |  |  |  | 238d | 24h |
| 282 | 8.3.5 | SE | 1d? | 2006-01-04 | 2006-01-04 |  |  |  | 238d | 80h |
| 283 | 8.4 | **modify/fab DWSM** | 1d? | 2006-01-04 | 2006-01-04 | 2006-01-04 | 2006-01-04 | 1d? | 238d | 440h |
| 284 | 8.4.1 | Sci | 1d? | 2006-01-04 | 2006-01-04 |  |  |  | 238d |  |
| 285 | 8.4.2 | Sci Tech | 1d? | 2006-01-04 | 2006-01-04 |  |  |  | 238d |  |
| 286 | 8.4.3 | EE | 1d? | 2006-01-04 | 2006-01-04 |  |  |  | 238d | 160h |
| 287 | 8.4.4 | ME | 1d? | 2006-01-04 | 2006-01-04 |  |  |  | 238d | 80h |
| 288 | 8.4.5 | SE | 1d? | 2006-01-04 | 2006-01-04 |  |  |  | 238d | 40h |
| 289 | 8.4.6 | ME Tech | 1d? | 2006-01-04 | 2006-01-04 |  |  |  | 238d | 80h |
| 290 | 8.4.7 | Shop | 1d? | 2006-01-04 | 2006-01-04 |  |  |  | 238d | 80h |
| 291 | 8.5 | **Modify/fab 2G** | 1d? | 2006-01-04 | 2006-01-04 | 2006-01-04 | 2006-01-04 | 1d? | 238d | 720h |
| 292 | 8.5.1 | Sci | 1d? | 2006-01-04 | 2006-01-04 |  |  |  | 238d |  |
| 293 | 8.5.2 | Sci Tech | 1d? | 2006-01-04 | 2006-01-04 |  |  |  | 238d |  |
| 294 | 8.5.3 | EE | 1d? | 2006-01-04 | 2006-01-04 |  |  |  | 238d | 160h |
| 295 | 8.5.4 | ME | 1d? | 2006-01-04 | 2006-01-04 |  |  |  | 238d | 80h |
| 296 | 8.5.5 | SE | 1d? | 2006-01-04 | 2006-01-04 |  |  |  | 238d | 80h |
| 297 | 8.5.6 | ME Tech | 1d? | 2006-01-04 | 2006-01-04 |  |  |  | 238d | 160h |
| 298 | 8.5.7 | EE Tech | 1d? | 2006-01-04 | 2006-01-04 |  |  |  | 238d | 80h |
| 299 | 8.5.8 | Shop | 1d? | 2006-01-04 | 2006-01-04 |  |  |  | 238d | 160h |

| ID | WBS | Task | Duration | Start | Finish | Baseline start | Baseline finish | Baseline duration | Total slack | Work |
| --- | --- | --- | --- | --- | --- | --- | --- | --- | --- | --- |
| 300 | 8.6 | **design/fab pressure housing** | 1d? | 2006-01-04 | 2006-01-04 | 2006-01-04 | 2006-01-04 | 1d? | 238d | 320h |
| 301 | 8.6.1 | Sci | 1d? | 2006-01-04 | 2006-01-04 |  |  |  | 238d |  |
| 302 | 8.6.2 | Sci Tech | 1d? | 2006-01-04 | 2006-01-04 |  |  |  | 238d |  |
| 303 | 8.6.3 | EE | 1d? | 2006-01-04 | 2006-01-04 |  |  |  | 238d | 40h |
| 304 | 8.6.4 | ME | 1d? | 2006-01-04 | 2006-01-04 |  |  |  | 238d | 80h |
| 305 | 8.6.5 | ME Tech | 1d? | 2006-01-04 | 2006-01-04 |  |  |  | 238d | 80h |
| 306 | 8.6.6 | EE Tech | 1d? | 2006-01-04 | 2006-01-04 |  |  |  | 238d | 40h |
| 307 | 8.6.7 | Shop | 1d? | 2006-01-04 | 2006-01-04 |  |  |  | 238d | 80h |
| 308 | 8.7 | **design/fab benthic mooring structure** | 1d? | 2006-01-04 | 2006-01-04 | 2006-01-04 | 2006-01-04 | 1d? | 238d | 240h |
| 309 | 8.7.1 | Sci | 1d? | 2006-01-04 | 2006-01-04 |  |  |  | 238d |  |
| 310 | 8.7.2 | Sci Tech | 1d? | 2006-01-04 | 2006-01-04 |  |  |  | 238d |  |
| 311 | 8.7.3 | EE | 1d? | 2006-01-04 | 2006-01-04 |  |  |  | 238d | 40h |
| 312 | 8.7.4 | ME | 1d? | 2006-01-04 | 2006-01-04 |  |  |  | 238d | 40h |
| 313 | 8.7.5 | ME Tech | 1d? | 2006-01-04 | 2006-01-04 |  |  |  | 238d | 80h |
| 314 | 8.7.6 | EE Tech | 1d? | 2006-01-04 | 2006-01-04 |  |  |  | 238d | 40h |
| 315 | 8.7.7 | Shop | 1d? | 2006-01-04 | 2006-01-04 |  |  |  | 238d | 40h |
| 316 | 8.8 | **Santa Monica Basin cruise?** | 1d? | 2006-01-04 | 2006-01-04 | 2006-01-04 | 2006-01-04 | 1d? | 238d |  |
| 317 | 8.8.1 | Sci | 1d? | 2006-01-04 | 2006-01-04 |  |  |  | 238d |  |
| 318 | 8.8.2 | Sci Tech | 1d? | 2006-01-04 | 2006-01-04 |  |  |  | 238d |  |
| 319 | 8.8.3 | EE | 1d? | 2006-01-04 | 2006-01-04 |  |  |  | 238d |  |
| 320 | 8.8.4 | ME | 1d? | 2006-01-04 | 2006-01-04 |  |  |  | 238d |  |
| 321 | 8.8.5 | SE | 1d? | 2006-01-04 | 2006-01-04 |  |  |  | 238d |  |
| 322 | 8.8.6 | ME Tech | 1d? | 2006-01-04 | 2006-01-04 |  |  |  | 238d |  |
| 323 | 8.8.7 | EE Tech | 1d? | 2006-01-04 | 2006-01-04 |  |  |  | 238d |  |
| 324 | 8.8.8 | Shop | 1d? | 2006-01-04 | 2006-01-04 |  |  |  | 238d |  |

| ID | WBS | Task | Duration | Start | Finish | Baseline start | Baseline finish | Baseline duration | Total slack | Work |
| --- | --- | --- | --- | --- | --- | --- | --- | --- | --- | --- |
| 326 | 9 | **Moore Foundation** | 1d? | 2006-01-04 | 2006-01-04 | 2006-01-04 | 2006-01-04 | 1d? | 238d | 1360h |
| 327 | 9.1 | **define functional requirements (w/ Zehr) - system concept devel** | 1d? | 2006-01-04 | 2006-01-04 | 2006-01-04 | 2006-01-04 | 1d? | 238d | 152h |
| 328 | 9.1.1 | Sci | 1d? | 2006-01-04 | 2006-01-04 |  |  |  | 238d |  |
| 329 | 9.1.2 | EE | 1d? | 2006-01-04 | 2006-01-04 |  |  |  | 238d | 40h |
| 330 | 9.1.3 | ME | 1d? | 2006-01-04 | 2006-01-04 |  |  |  | 238d | 80h |
| 331 | 9.1.4 | SE | 1d? | 2006-01-04 | 2006-01-04 |  |  |  | 238d | 32h |
| 332 | 9.2 | **evaluate existing analytical modules - candidacy** | 1d? | 2006-01-04 | 2006-01-04 | 2006-01-04 | 2006-01-04 | 1d? | 238d | 224h |
| 333 | 9.2.1 | Sci | 1d? | 2006-01-04 | 2006-01-04 |  |  |  | 238d |  |
| 334 | 9.2.2 | EE | 1d? | 2006-01-04 | 2006-01-04 |  |  |  | 238d | 80h |
| 335 | 9.2.3 | ME | 1d? | 2006-01-04 | 2006-01-04 |  |  |  | 238d | 120h |
| 336 | 9.2.4 | SE | 1d? | 2006-01-04 | 2006-01-04 |  |  |  | 238d | 24h |
| 337 | 9.3 | **downselect candidate modules - develop test plan** | 1d? | 2006-01-04 | 2006-01-04 | 2006-01-04 | 2006-01-04 | 1d? | 238d | 88h |
| 338 | 9.3.1 | Sci | 1d? | 2006-01-04 | 2006-01-04 |  |  |  | 238d |  |
| 339 | 9.3.2 | EE | 1d? | 2006-01-04 | 2006-01-04 |  |  |  | 238d | 24h |
| 340 | 9.3.3 | ME | 1d? | 2006-01-04 | 2006-01-04 |  |  |  | 238d | 40h |
| 341 | 9.3.4 | SE | 1d? | 2006-01-04 | 2006-01-04 |  |  |  | 238d | 24h |
| 342 | 9.4 | **develop lab test fixture that incorps elements of ESP and analytical modules** | 1d? | 2006-01-04 | 2006-01-04 | 2006-01-04 | 2006-01-04 | 1d? | 238d | 896h |
| 343 | 9.4.1 | Sci | 1d? | 2006-01-04 | 2006-01-04 |  |  |  | 238d |  |
| 344 | 9.4.2 | EE | 1d? | 2006-01-04 | 2006-01-04 |  |  |  | 238d | 176h |
| 345 | 9.4.3 | ME | 1d? | 2006-01-04 | 2006-01-04 |  |  |  | 238d | 240h |
| 346 | 9.4.4 | SE | 1d? | 2006-01-04 | 2006-01-04 |  |  |  | 238d | 80h |
| 347 | 9.4.5 | ME Tech | 1d? | 2006-01-04 | 2006-01-04 |  |  |  | 238d | 160h |
| 348 | 9.4.6 | EE Tech | 1d? | 2006-01-04 | 2006-01-04 |  |  |  | 238d | 80h |
| 349 | 9.4.7 | Shop | 1d? | 2006-01-04 | 2006-01-04 |  |  |  | 238d | 160h |
