# ESP schedule

Schedule from MS Project, 2005-12-14 to 2006-12-04, A marks actual dates.
MBARI

## Calendars

- Standard: Mon-Fri 08:00-12:00, 13:00-17:00; Sat-Sun off.

## Resources

| Resource |
| --- |
| Scott |
| Gene |
| Brent |
| Chris S. |
| Chris P. |
| Roman |
| Mark Brown |
| Science Team |
| Bob |

## Schedule

| ID | WBS | Task | Type | Duration | Start | Finish | Complete | Remaining | Baseline start | Baseline finish | Baseline duration | Total slack | Constraint | Resources | Work | Actual work |
| --- | --- | --- | --- | --- | --- | --- | --- | --- | --- | --- | --- | --- | --- | --- | --- | --- |
| 1 | 1 | **GiGi core** |  | 55d? | 2005-12-14 A | 2006-02-28 | 14% | 47.19d? | 2005-12-14 | 2006-01-04 | 16d? | 199d |  |  | 828h | 36h |
| 2 | 1.1 | Final instrument modifications |  | 1d? | 2006-01-04 | 2006-01-04 |  |  | 2006-01-04 | 2006-01-04 | 1d? | 238d |  |  |  |  |
| 4 | 1.2 | **Refit system valves to Cheminert valves** |  | 40d? | 2005-12-14 A | 2006-02-07 | 41% | 23.68d? | 2005-12-14 | 2006-01-04 | 16d? | 214d |  |  | 148h | 36h |
| 5 | 1.2.1 | Order new valves |  | 0.5d | 2005-12-14 A | 2005-12-14 A | 100% |  | 2005-12-14 | 2005-12-14 | 0.5d |  | start no earlier than 2005-12-14 | Scott | 4h | 4h |
| 6 | 1.2.2 | Split cost of valves | milestone | 0d | 2006-01-04 | 2006-01-04 |  |  | 2006-01-04 | 2006-01-04 | 0d? | 239d |  |  |  |  |
| 7 | 1.2.3 | Valves arrive | milestone | 0d | 2006-01-04 | 2006-01-04 |  |  | 2006-01-04 | 2006-01-04 | 1d? | 239d |  |  |  |  |
| 8 | 1.2.4 | **Valve bracket redesign** |  | 2d? | 2006-01-04 A | 2006-01-05 A | 100% |  | 2006-01-04 | 2006-01-04 | 1d? |  |  |  | 32h | 32h |
| 9 | 1.2.4.1 | **Design** |  | 2d? | 2006-01-04 A | 2006-01-05 A | 100% |  | 2006-01-04 | 2006-01-04 | 1d? |  |  |  | 24h | 24h |
| 10 | 1.2.4.1.1 | EE |  | 1.43d? | 2006-01-04 A | 2006-01-05 A | 100% |  | 2006-01-04 | 2006-01-04 | 1d? |  |  | Scott [70%] | 8h | 8h |
| 11 | 1.2.4.1.2 | ME |  | 2d? | 2006-01-04 A | 2006-01-05 A | 100% |  | 2006-01-04 | 2006-01-04 | 1d? |  |  | Gene [50%] | 8h | 8h |
| 12 | 1.2.4.1.3 | SE |  | 1.43d? | 2006-01-04 A | 2006-01-05 A | 100% |  | 2006-01-04 | 2006-01-04 | 1d? |  |  | Brent [70%] | 8h | 8h |
| 13 | 1.2.4.2 | **Part procurment** |  | 2d? | 2006-01-04 A | 2006-01-05 A | 100% |  | 2006-01-04 | 2006-01-04 | 1d? |  |  |  | 8h | 8h |
| 14 | 1.2.4.2.1 | ME Tech |  | 1d? | 2006-01-04 A | 2006-01-04 A | 100% |  | 2006-01-04 | 2006-01-04 | 1d? |  |  |  |  |  |
| 15 | 1.2.4.2.2 | ME |  | 2d? | 2006-01-04 A | 2006-01-05 A | 100% |  | 2006-01-04 | 2006-01-04 | 1d? |  |  | Gene [50%] | 8h | 8h |
| 16 | 1.2.4.3 | **fabrication** |  | 1d? | 2006-01-04 A | 2006-01-04 A | 100% |  | 2006-01-04 | 2006-01-04 | 1d? |  |  |  |  |  |
| 17 | 1.2.4.3.1 | METech |  | 1d? | 2006-01-04 A | 2006-01-04 A | 100% |  | 2006-01-04 | 2006-01-04 | 1d? |  |  |  |  |  |
| 18 | 1.2.4.3.2 | ME |  | 1d? | 2006-01-04 A | 2006-01-04 A | 100% |  | 2006-01-04 | 2006-01-04 | 1d? |  |  |  |  |  |
| 19 | 1.2.4.3.3 | EE |  | 1d? | 2006-01-04 A | 2006-01-04 A | 100% |  | 2006-01-04 | 2006-01-04 | 1d? |  |  |  |  |  |
| 20 | 1.2.4.4 | **Assembly** |  | 1d? | 2006-01-04 A | 2006-01-04 A | 100% |  | 2006-01-04 | 2006-01-04 | 1d? |  |  |  |  |  |
| 21 | 1.2.4.4.1 | ME Tech |  | 1d? | 2006-01-04 A | 2006-01-04 A | 100% |  | 2006-01-04 | 2006-01-04 | 1d? |  |  |  |  |  |
| 22 | 1.2.5 | **Valve placement in instrument** |  | 1d? | 2006-01-04 A | 2006-01-04 | 90% | 0.1d? | 2006-01-04 | 2006-01-04 | 1d? | 238d |  |  |  |  |
| 23 | 1.2.5.1 | Physical modelling for valve placement |  | 1d? | 2006-01-04 A | 2006-01-04 A | 100% |  | 2006-01-04 | 2006-01-04 | 1d? |  |  |  |  |  |
| 24 | 1.2.5.2 | **Instrument modifications** |  | 1d? | 2006-01-04 A | 2006-01-04 A | 100% |  | 2006-01-04 | 2006-01-04 | 1d? |  |  |  |  |  |
| 25 | 1.2.5.2.1 | **Fabrication** |  | 1d? | 2006-01-04 A | 2006-01-04 A | 100% |  | 2006-01-04 | 2006-01-04 | 1d? |  |  |  |  |  |
| 26 | 1.2.5.2.1.1 | ME tech |  | 1d? | 2006-01-04 A | 2006-01-04 A | 100% |  | 2006-01-04 | 2006-01-04 | 1d? |  |  |  |  |  |
| 27 | 1.2.5.2.1.2 | ME |  | 1d? | 2006-01-04 A | 2006-01-04 A | 100% |  | 2006-01-04 | 2006-01-04 | 1d? |  |  |  |  |  |
| 28 | 1.2.5.2.1.3 | shop |  | 1d? | 2006-01-04 A | 2006-01-04 A | 100% |  | 2006-01-04 | 2006-01-04 | 1d? |  |  |  |  |  |

Notes:
- 5: Placed order with VICI with two PO's / PO-0512876 4,6,8 using C25-618x vavles / PO-0512876 for custom 4 port loop C22-6184-MBA / Custom was $base+25 and +1wk
- 7: Standard valves arrived ealry than planned 12/21/05 / Waiting for custom

| ID | WBS | Task | Duration | Start | Finish | Complete | Baseline start | Baseline finish | Baseline duration | Total slack | Constraint | Resources | Work |
| --- | --- | --- | --- | --- | --- | --- | --- | --- | --- | --- | --- | --- | --- |
| 29 | 1.2.5.2.2 | **assembly** | 1d? | 2006-01-04 A | 2006-01-04 A | 100% | 2006-01-04 | 2006-01-04 | 1d? |  |  |  |  |
| 30 | 1.2.5.2.2.1 | ME tech | 1d? | 2006-01-04 A | 2006-01-04 A | 100% | 2006-01-04 | 2006-01-04 | 1d? |  |  |  |  |
| 31 | 1.2.5.2.2.2 | ME | 1d? | 2006-01-04 A | 2006-01-04 A | 100% | 2006-01-04 | 2006-01-04 | 1d? |  |  |  |  |
| 32 | 1.2.5.2.2.3 | shop | 1d? | 2006-01-04 A | 2006-01-04 A | 100% | 2006-01-04 | 2006-01-04 | 1d? |  |  |  |  |
| 33 | 1.2.5.2.2.4 | EE | 1d? | 2006-01-04 A | 2006-01-04 A | 100% | 2006-01-04 | 2006-01-04 | 1d? |  |  |  |  |
| 34 | 1.2.5.2.2.5 | SE | 1d? | 2006-01-04 A | 2006-01-04 A | 100% | 2006-01-04 | 2006-01-04 | 1d? |  |  |  |  |
| 35 | 1.2.5.3 | **Testing** | 1d? | 2006-01-04 | 2006-01-04 |  | 2006-01-04 | 2006-01-04 | 1d? | 238d |  |  |  |
| 36 | 1.2.5.3.1 | EE | 1d? | 2006-01-04 | 2006-01-04 |  | 2006-01-04 | 2006-01-04 | 1d? | 238d |  |  |  |
| 37 | 1.2.6 | Protocol redevelopment | 10d | 2006-01-25 | 2006-02-07 |  | 2006-01-04 | 2006-01-04 | 1d? | 214d | start no earlier than 2006-01-25 | Science Team | 80h |
| 38 | 1.2.7 | **Refit completion** | 20d? | 2006-01-04 | 2006-01-31 |  | 2006-01-04 | 2006-01-04 | 1d? | 219d |  |  | 32h |
| 39 | 1.2.7.1 | Model and drawing update - MB | 20d? | 2006-01-04 | 2006-01-31 |  | 2006-01-04 | 2006-01-04 | 1d? | 219d |  | Mark Brown [20%] | 32h |
| 41 | 1.3 | **modify bulkhead valves - eliminate solenoid** | 1d? | 2006-01-04 | 2006-01-04 |  | 2006-01-04 | 2006-01-04 | 1d? | 238d |  |  | 280h |
| 42 | 1.3.1 | **design** | 1d? | 2006-01-04 | 2006-01-04 |  | 2006-01-04 | 2006-01-04 | 1d? | 238d |  |  | 112h |
| 43 | 1.3.1.1 | EE | 1d? | 2006-01-04 | 2006-01-04 |  | 2006-01-04 | 2006-01-04 | 1d? | 238d |  |  | 40h |
| 44 | 1.3.1.2 | ME | 1d? | 2006-01-04 | 2006-01-04 |  | 2006-01-04 | 2006-01-04 | 1d? | 238d |  |  | 56h |
| 45 | 1.3.1.3 | SE | 1d? | 2006-01-04 | 2006-01-04 |  | 2006-01-04 | 2006-01-04 | 1d? | 238d |  |  | 16h |
| 46 | 1.3.2 | **Fabricate** | 1d? | 2006-01-04 | 2006-01-04 |  | 2006-01-04 | 2006-01-04 | 1d? | 238d |  |  | 72h |
| 47 | 1.3.2.1 | EE | 1d? | 2006-01-04 | 2006-01-04 |  | 2006-01-04 | 2006-01-04 | 1d? | 238d |  |  | 16h |
| 48 | 1.3.2.2 | ME | 1d? | 2006-01-04 | 2006-01-04 |  | 2006-01-04 | 2006-01-04 | 1d? | 238d |  |  | 8h |
| 49 | 1.3.2.3 | ME Tech | 1d? | 2006-01-04 | 2006-01-04 |  | 2006-01-04 | 2006-01-04 | 1d? | 238d |  |  | 16h |
| 50 | 1.3.2.4 | EE Tech | 1d? | 2006-01-04 | 2006-01-04 |  | 2006-01-04 | 2006-01-04 | 1d? | 238d |  |  | 8h |
| 51 | 1.3.2.5 | Shop | 1d? | 2006-01-04 | 2006-01-04 |  | 2006-01-04 | 2006-01-04 | 1d? | 238d |  |  | 24h |
| 52 | 1.3.3 | **test and integrate** | 1d? | 2006-01-04 | 2006-01-04 |  | 2006-01-04 | 2006-01-04 | 1d? | 238d |  |  | 96h |
| 53 | 1.3.3.1 | EE | 1d? | 2006-01-04 | 2006-01-04 |  | 2006-01-04 | 2006-01-04 | 1d? | 238d |  |  | 40h |
| 54 | 1.3.3.2 | ME | 1d? | 2006-01-04 | 2006-01-04 |  | 2006-01-04 | 2006-01-04 | 1d? | 238d |  |  | 16h |
| 55 | 1.3.3.3 | SE | 1d? | 2006-01-04 | 2006-01-04 |  | 2006-01-04 | 2006-01-04 | 1d? | 238d |  |  | 16h |
| 56 | 1.3.3.4 | ME Tech | 1d? | 2006-01-04 | 2006-01-04 |  | 2006-01-04 | 2006-01-04 | 1d? | 238d |  |  | 24h |

| ID | WBS | Task | Duration | Start | Finish | Baseline start | Baseline finish | Baseline duration | Total slack | Free slack | Constraint | Resources | Work |
| --- | --- | --- | --- | --- | --- | --- | --- | --- | --- | --- | --- | --- | --- |
| 58 | 1.4 | **Software** | 40d | 2006-01-04 | 2006-02-28 | 2006-01-04 | 2006-02-28 | 40d | 187d |  |  |  | 400h |
| 59 | 1.4.1 | **Contextual Sensors** | 30d | 2006-01-04 | 2006-02-14 | 2006-01-04 | 2006-02-14 | 30d | 209d |  |  |  | 280h |
| 60 | 1.4.1.1 | SE | 30d | 2006-01-04 | 2006-02-14 | 2006-01-04 | 2006-02-14 | 30d | 209d |  |  | Brent [16.7%] | 40h |
| 61 | 1.4.1.2 | External SE | 30d | 2006-01-04 | 2006-02-14 | 2006-01-04 | 2006-02-14 | 30d | 209d |  |  | Bob | 240h |
| 62 | 1.4.2 | Power cycling | 25d | 2006-01-25 | 2006-02-28 | 2006-01-25 | 2006-02-28 | 25d | 181d | 0d | start no earlier than 2006-01-25 | Brent [60%] | 120h |
| 64 | 2 | **shutter on sample intake port (50m depth max)** | 1d? | 2006-01-04 | 2006-01-04 | 2006-01-04 | 2006-01-04 | 1d? | 238d |  |  |  | 328h |
| 65 | 2.1 | **design** | 1d? | 2006-01-04 | 2006-01-04 | 2006-01-04 | 2006-01-04 | 1d? | 238d |  |  |  | 120h |
| 66 | 2.1.1 | EE | 1d? | 2006-01-04 | 2006-01-04 | 2006-01-04 | 2006-01-04 | 1d? | 238d |  |  |  | 40h |
| 67 | 2.1.2 | ME | 1d? | 2006-01-04 | 2006-01-04 | 2006-01-04 | 2006-01-04 | 1d? | 238d |  |  |  | 64h |
| 68 | 2.1.3 | SE | 1d? | 2006-01-04 | 2006-01-04 | 2006-01-04 | 2006-01-04 | 1d? | 238d |  |  |  | 16h |
| 69 | 2.2 | **Fabricate** | 1d? | 2006-01-04 | 2006-01-04 | 2006-01-04 | 2006-01-04 | 1d? | 238d |  |  |  | 112h |
| 70 | 2.2.1 | EE | 1d? | 2006-01-04 | 2006-01-04 | 2006-01-04 | 2006-01-04 | 1d? | 238d |  |  |  | 16h |
| 71 | 2.2.2 | ME | 1d? | 2006-01-04 | 2006-01-04 | 2006-01-04 | 2006-01-04 | 1d? | 238d |  |  |  | 8h |
| 72 | 2.2.3 | ME Tech | 1d? | 2006-01-04 | 2006-01-04 | 2006-01-04 | 2006-01-04 | 1d? | 238d |  |  |  | 16h |
| 73 | 2.2.4 | EE Tech | 1d? | 2006-01-04 | 2006-01-04 | 2006-01-04 | 2006-01-04 | 1d? | 238d |  |  |  | 8h |
| 74 | 2.2.5 | Shop | 1d? | 2006-01-04 | 2006-01-04 | 2006-01-04 | 2006-01-04 | 1d? | 238d |  |  |  | 64h |
| 75 | 2.3 | **test and integrate** | 1d? | 2006-01-04 | 2006-01-04 | 2006-01-04 | 2006-01-04 | 1d? | 238d |  |  |  | 96h |
| 76 | 2.3.1 | EE | 1d? | 2006-01-04 | 2006-01-04 | 2006-01-04 | 2006-01-04 | 1d? | 238d |  |  |  | 40h |
| 77 | 2.3.2 | ME | 1d? | 2006-01-04 | 2006-01-04 | 2006-01-04 | 2006-01-04 | 1d? | 238d |  |  |  | 16h |
| 78 | 2.3.3 | SE | 1d? | 2006-01-04 | 2006-01-04 | 2006-01-04 | 2006-01-04 | 1d? | 238d |  |  |  | 16h |
| 79 | 2.3.4 | ME Tech | 1d? | 2006-01-04 | 2006-01-04 | 2006-01-04 | 2006-01-04 | 1d? | 238d |  |  |  | 24h |
| 81 | 3 | **Software** | 1d? | 2006-01-04 | 2006-01-04 | 2006-01-04 | 2006-01-04 | 1d? | 238d |  |  |  | 280h |
| 82 | 3.1 | GUI | 1d? | 2006-01-04 | 2006-01-04 | 2006-01-04 | 2006-01-04 | 1d? | 238d |  |  |  |  |
| 83 | 3.2 | annimator | 1d? | 2006-01-04 | 2006-01-04 | 2006-01-04 | 2006-01-04 | 1d? | 238d |  |  |  | 280h |

| ID | WBS | Task | Duration | Start | Finish | Predecessors | Baseline start | Baseline finish | Baseline duration | Total slack | Free slack | Constraint | Resources | Work |
| --- | --- | --- | --- | --- | --- | --- | --- | --- | --- | --- | --- | --- | --- | --- |
| 85 | 4 | **Finish surface surface water housing for GiGi** | 35d | 2006-01-25 | 2006-03-14 |  | 2006-01-04 | 2006-01-04 | 1d? | 189d |  |  |  | 24h |
| 86 | 4.1 | **Pressure housing for GiGi - surface water - 50m** | 35d | 2006-01-25 | 2006-03-14 |  | 2006-01-04 | 2006-01-04 | 1d? | 189d |  |  |  | 24h |
| 87 | 4.1.1 | **Design** | 8d | 2006-01-25 | 2006-02-03 |  | 2006-01-04 | 2006-01-04 | 1d? | 189d | 0d |  |  | 8h |
| 88 | 4.1.1.1 | ME | 8d | 2006-01-25 | 2006-02-03 |  | 2006-01-25 | 2006-02-03 | 8d | 189d |  | start no earlier than 2006-01-25 | Gene [12.5%] | 8h |
| 89 | 4.1.2 | **assembly** | 25d | 2006-02-06 | 2006-03-10 | 87 | 2006-01-04 | 2006-01-04 | 1d? | 189d | 0d |  |  | 8h |
| 90 | 4.1.2.1 | Outside fab | 25d | 2006-02-06 | 2006-03-10 |  | 2006-02-06 | 2006-03-10 | 25d | 189d |  |  |  |  |
| 91 | 4.1.2.2 | ME tech | 2d | 2006-02-06 | 2006-02-07 |  | 2006-02-06 | 2006-02-07 | 2d | 212d |  |  |  | 8h |
| 92 | 4.1.3 | **Pressure test** | 2d | 2006-03-13 | 2006-03-14 | 89 | 2006-01-04 | 2006-01-04 | 1d? | 189d |  |  |  | 8h |
| 93 | 4.1.3.1 | ME tech | 2d | 2006-03-13 | 2006-03-14 |  | 2006-03-13 | 2006-03-14 | 2d | 189d |  |  |  | 8h |
| 95 | 5 | **Mooring 2 battery configuration** | 27d? | 2006-01-04 | 2006-02-09 |  | 2006-01-04 | 2006-02-09 | 27d? | 191d |  |  |  |  |
| 96 | 5.1 | Mechanical | 1d? | 2006-01-04 | 2006-01-04 |  | 2006-01-04 | 2006-01-04 | 1d? | 216d | 0d |  |  |  |
| 97 | 5.2 | **Electrical** | 1d? | 2006-02-09 | 2006-02-09 | 96 | 2006-02-09 | 2006-02-09 | 1d? | 191d | 15d |  |  |  |
| 98 | 5.2.1 | Battery order | 1d? | 2006-02-09 | 2006-02-09 |  | 2006-02-09 | 2006-02-09 | 1d? | 191d |  | finish no earlier than 2006-02-09 |  |  |
| 99 | 5.2.2 | Cable configuration | 1d? | 2006-02-09 | 2006-02-09 |  | 2006-02-09 | 2006-02-09 | 1d? | 191d |  | finish no earlier than 2006-02-09 |  |  |
| 105 | 6 | Tank Deployment | 1d? | 2006-03-03 | 2006-03-03 | 97 | 2006-03-03 | 2006-03-03 | 1d? | 176d | 2d | start no earlier than 2006-03-03 |  |  |
| 108 | 7 | **Shallow water deployments** | 149d? | 2006-03-08 | 2006-10-02 | 105 | 2006-01-04 | 2006-03-08 | 45d? | 45d |  |  |  | 480h |
| 109 | 7.1 | **Deployment 1** | 14d? | 2006-03-08 | 2006-03-27 |  | 2006-01-04 | 2006-03-08 | 45d? | 180d |  |  |  | 52h |
| 110 | 7.1.1 | MOB | 1d | 2006-03-08 | 2006-03-09 | 114SF | 2006-01-04 | 2006-01-04 | 1d? | 192d | 0d | start no earlier than 2006-03-08 |  |  |
| 111 | 7.1.2 | **MOB resources** | 1d? | 2006-03-08 | 2006-03-08 | 110SS | 2006-03-08 | 2006-03-08 | 1d? | 193d |  |  |  | 12h |
| 112 | 7.1.2.1 | EE | 1d? | 2006-03-08 | 2006-03-08 |  | 2006-03-08 | 2006-03-08 | 1d? | 193d |  |  |  | 8h |
| 113 | 7.1.2.2 | ME | 1d? | 2006-03-08 | 2006-03-08 |  | 2006-03-08 | 2006-03-08 | 1d? | 193d |  |  |  | 4h |
| 114 | 7.1.3 | Deployment | 13d | 2006-03-09 | 2006-03-27 |  | 2006-03-08 | 2006-03-08 | 13d | 180d | 0d | start no earlier than 2006-03-09 |  |  |
| 115 | 7.1.4 | **Deployment resources** | 13d? | 2006-03-09 | 2006-03-27 |  | 2006-03-09 | 2006-03-27 | 13d? | 180d |  |  |  | 40h |
| 116 | 7.1.4.1 | **Deploy** | 1d? | 2006-03-09 | 2006-03-09 | 114SS | 2006-03-09 | 2006-03-09 | 1d? | 192d |  |  |  | 20h |
| 117 | 7.1.4.1.1 | EE | 1d? | 2006-03-09 | 2006-03-09 |  | 2006-03-09 | 2006-03-09 | 1d? | 192d |  |  |  | 12h |
| 118 | 7.1.4.1.2 | ME | 1d? | 2006-03-09 | 2006-03-09 |  | 2006-03-09 | 2006-03-09 | 1d? | 192d |  |  |  | 8h |

| ID | WBS | Task | Duration | Start | Finish | Predecessors | Baseline start | Baseline finish | Baseline duration | Total slack | Free slack | Constraint | Work |
| --- | --- | --- | --- | --- | --- | --- | --- | --- | --- | --- | --- | --- | --- |
| 119 | 7.1.4.2 | **Recover** | 2d | 2006-03-24 | 2006-03-27 |  | 2006-03-24 | 2006-03-27 | 2d | 180d |  |  | 20h |
| 120 | 7.1.4.2.1 | EE | 2d | 2006-03-24 | 2006-03-27 | 114FF | 2006-03-24 | 2006-03-27 | 2d | 180d |  |  | 12h |
| 121 | 7.1.4.2.2 | ME | 2d | 2006-03-24 | 2006-03-27 | 114FF | 2006-03-24 | 2006-03-27 | 2d | 180d |  |  | 8h |
| 122 | 7.2 | **Deployment 2** | 16d? | 2006-04-03 | 2006-04-24 |  | 2006-01-04 | 2006-03-08 | 45d? | 160d |  |  | 36h |
| 123 | 7.2.1 | MOB | 1d | 2006-04-03 | 2006-04-03 | 127SS | 2006-01-04 | 2006-01-04 | 1d? | 175d | 0d | start no earlier than 2006-03-08 |  |
| 124 | 7.2.2 | **MOB resources** | 1d? | 2006-04-03 | 2006-04-03 | 123SS | 2006-04-03 | 2006-04-03 | 1d? | 175d |  |  | 12h |
| 125 | 7.2.2.1 | EE | 1d? | 2006-04-03 | 2006-04-03 |  | 2006-04-03 | 2006-04-03 | 1d? | 175d |  |  | 8h |
| 126 | 7.2.2.2 | ME | 1d? | 2006-04-03 | 2006-04-03 |  | 2006-04-03 | 2006-04-03 | 1d? | 175d |  |  | 4h |
| 127 | 7.2.3 | Deployment | 16d | 2006-04-03 | 2006-04-24 |  | 2006-03-08 | 2006-03-08 | 16d | 160d | 0d | finish no earlier than 2006-04-24 |  |
| 128 | 7.2.4 | **Deployment resources** | 16d? | 2006-04-03 | 2006-04-24 |  | 2006-04-03 | 2006-04-24 | 16d? | 160d |  |  | 24h |
| 129 | 7.2.4.1 | **Deploy** | 1d? | 2006-04-03 | 2006-04-03 | 127SS | 2006-04-03 | 2006-04-03 | 1d? | 175d |  |  | 16h |
| 130 | 7.2.4.1.1 | EE | 1d? | 2006-04-03 | 2006-04-03 |  | 2006-04-03 | 2006-04-03 | 1d? | 175d |  |  | 8h |
| 131 | 7.2.4.1.2 | ME | 1d? | 2006-04-03 | 2006-04-03 |  | 2006-04-03 | 2006-04-03 | 1d? | 175d |  |  | 8h |
| 132 | 7.2.4.2 | **Recover** | 2d | 2006-04-21 | 2006-04-24 |  | 2006-04-21 | 2006-04-24 | 2d | 160d |  |  | 8h |
| 133 | 7.2.4.2.1 | EE | 2d | 2006-04-21 | 2006-04-24 | 127FF | 2006-04-21 | 2006-04-24 | 2d | 160d |  |  | 8h |
| 134 | 7.2.4.2.2 | ME | 2d | 2006-04-21 | 2006-04-24 | 127FF | 2006-04-21 | 2006-04-24 | 2d | 160d |  |  |  |
| 135 | 7.3 | **Deployment 3** | 10d? | 2006-05-01 | 2006-05-12 |  | 2006-01-04 | 2006-03-08 | 45d? | 146d |  |  | 24h |
| 136 | 7.3.1 | MOB | 1d | 2006-05-01 | 2006-05-01 | 139SS | 2006-01-04 | 2006-01-04 | 1d? | 155d | 0d | start no earlier than 2006-03-08 |  |
| 137 | 7.3.2 | **MOB resources** | 1d? | 2006-05-01 | 2006-05-01 | 136SS | 2006-05-01 | 2006-05-01 | 1d? | 155d |  |  | 8h |
| 138 | 7.3.2.1 | EE | 1d? | 2006-05-01 | 2006-05-01 |  | 2006-05-01 | 2006-05-01 | 1d? | 155d |  |  | 8h |
| 139 | 7.3.3 | Deployment | 10d | 2006-05-01 | 2006-05-12 |  | 2006-03-08 | 2006-03-08 | 10d | 146d | 0d | start no earlier than 2006-05-01 |  |
| 140 | 7.3.4 | **Deployment resources** | 10d? | 2006-05-01 | 2006-05-12 |  | 2006-05-01 | 2006-05-12 | 10d? | 146d |  |  | 16h |
| 141 | 7.3.4.1 | **Deploy** | 1d? | 2006-05-01 | 2006-05-01 | 139SS | 2006-05-01 | 2006-05-01 | 1d? | 155d |  |  | 8h |
| 142 | 7.3.4.1.1 | EE | 1d? | 2006-05-01 | 2006-05-01 |  | 2006-05-01 | 2006-05-01 | 1d? | 155d |  |  | 8h |

| ID | WBS | Task | Duration | Start | Finish | Predecessors | Baseline start | Baseline finish | Baseline duration | Total slack | Free slack | Constraint | Work |
| --- | --- | --- | --- | --- | --- | --- | --- | --- | --- | --- | --- | --- | --- |
| 143 | 7.3.4.2 | **Recover** | 2d | 2006-05-11 | 2006-05-12 |  | 2006-05-11 | 2006-05-12 | 2d | 146d |  |  | 8h |
| 144 | 7.3.4.2.1 | EE | 2d | 2006-05-11 | 2006-05-12 | 139FF | 2006-05-11 | 2006-05-12 | 2d | 146d |  |  | 8h |
| 145 | 7.4 | **Deployment 4** | 20d? | 2006-05-30 | 2006-06-26 |  | 2006-01-04 | 2006-03-08 | 45d? | 115d |  |  | 24h |
| 146 | 7.4.1 | MOB | 1d | 2006-05-30 | 2006-05-30 | 149SS | 2006-01-04 | 2006-01-04 | 1d? | 134d | 0d | start no earlier than 2006-03-08 |  |
| 147 | 7.4.2 | **MOB resources** | 1d? | 2006-05-30 | 2006-05-30 | 146SS | 2006-05-30 | 2006-05-30 | 1d? | 134d |  |  | 8h |
| 148 | 7.4.2.1 | EE | 1d? | 2006-05-30 | 2006-05-30 |  | 2006-05-30 | 2006-05-30 | 1d? | 134d |  |  | 8h |
| 149 | 7.4.3 | Deployment | 20d | 2006-05-30 | 2006-06-26 |  | 2006-03-08 | 2006-03-08 | 20d | 115d | 0d | start no earlier than 2006-05-30 |  |
| 150 | 7.4.4 | **Deployment resources** | 20d? | 2006-05-30 | 2006-06-26 |  | 2006-05-30 | 2006-06-26 | 20d? | 115d |  |  | 16h |
| 151 | 7.4.4.1 | **Deploy** | 1d? | 2006-05-30 | 2006-05-30 | 149SS | 2006-05-30 | 2006-05-30 | 1d? | 134d |  |  | 8h |
| 152 | 7.4.4.1.1 | EE | 1d? | 2006-05-30 | 2006-05-30 |  | 2006-05-30 | 2006-05-30 | 1d? | 134d |  |  | 8h |
| 153 | 7.4.4.2 | **Recover** | 2d | 2006-06-23 | 2006-06-26 |  | 2006-06-23 | 2006-06-26 | 2d | 115d |  |  | 8h |
| 154 | 7.4.4.2.1 | EE | 2d | 2006-06-23 | 2006-06-26 | 149FF | 2006-06-23 | 2006-06-26 | 2d | 115d |  |  | 8h |
| 155 | 7.5 | **Deployment 5** | 14d? | 2006-07-05 | 2006-07-24 |  | 2006-01-04 | 2006-03-08 | 45d? | 95d |  |  | 24h |
| 156 | 7.5.1 | MOB | 1d | 2006-07-05 | 2006-07-05 | 159SS | 2006-01-04 | 2006-01-04 | 1d? | 108d | 0d | start no earlier than 2006-03-08 |  |
| 157 | 7.5.2 | **MOB resources** | 1d? | 2006-07-05 | 2006-07-05 | 156SS | 2006-07-05 | 2006-07-05 | 1d? | 108d |  |  | 8h |
| 158 | 7.5.2.1 | EE | 1d? | 2006-07-05 | 2006-07-05 |  | 2006-07-05 | 2006-07-05 | 1d? | 108d |  |  | 8h |
| 159 | 7.5.3 | Deployment | 14d | 2006-07-05 | 2006-07-24 |  | 2006-03-08 | 2006-03-08 | 14d | 95d | 0d | start no earlier than 2006-07-05 |  |
| 160 | 7.5.4 | **Deployment resources** | 14d? | 2006-07-05 | 2006-07-24 |  | 2006-07-05 | 2006-07-24 | 14d? | 95d |  |  | 16h |
| 161 | 7.5.4.1 | **Deploy** | 1d? | 2006-07-05 | 2006-07-05 | 159SS | 2006-07-05 | 2006-07-05 | 1d? | 108d |  |  | 8h |
| 162 | 7.5.4.1.1 | EE | 1d? | 2006-07-05 | 2006-07-05 |  | 2006-07-05 | 2006-07-05 | 1d? | 108d |  |  | 8h |
| 163 | 7.5.4.2 | **Recover** | 2d | 2006-07-21 | 2006-07-24 |  | 2006-07-21 | 2006-07-24 | 2d | 95d |  |  | 8h |
| 164 | 7.5.4.2.1 | EE | 2d | 2006-07-21 | 2006-07-24 | 159FF | 2006-07-21 | 2006-07-24 | 2d | 95d |  |  | 8h |
| 165 | 7.6 | **Deployment 6** | 17d? | 2006-09-08 | 2006-10-02 |  | 2006-01-04 | 2006-03-08 | 45d? | 45d |  |  | 24h |
| 166 | 7.6.1 | MOB | 1d | 2006-09-08 | 2006-09-08 | 169SS | 2006-01-04 | 2006-01-04 | 1d? | 61d | 0d | start no earlier than 2006-03-08 |  |

| ID | WBS | Task | Duration | Start | Finish | Predecessors | Baseline start | Baseline finish | Baseline duration | Total slack | Free slack | Constraint | Work |
| --- | --- | --- | --- | --- | --- | --- | --- | --- | --- | --- | --- | --- | --- |
| 167 | 7.6.2 | **MOB resources** | 1d? | 2006-09-08 | 2006-09-08 | 166SS | 2006-09-08 | 2006-09-08 | 1d? | 61d |  |  | 8h |
| 168 | 7.6.2.1 | EE | 1d? | 2006-09-08 | 2006-09-08 |  | 2006-09-08 | 2006-09-08 | 1d? | 61d |  |  | 8h |
| 169 | 7.6.3 | Deployment | 17d | 2006-09-08 | 2006-10-02 |  | 2006-03-08 | 2006-03-08 | 17d | 45d | 0d | start no earlier than 2006-09-08 |  |
| 170 | 7.6.4 | **Deployment resources** | 17d? | 2006-09-08 | 2006-10-02 |  | 2006-09-08 | 2006-10-02 | 17d? | 45d |  |  | 16h |
| 171 | 7.6.4.1 | **Deploy** | 1d? | 2006-09-08 | 2006-09-08 | 169SS | 2006-09-08 | 2006-09-08 | 1d? | 61d |  |  | 8h |
| 172 | 7.6.4.1.1 | EE | 1d? | 2006-09-08 | 2006-09-08 |  | 2006-09-08 | 2006-09-08 | 1d? | 61d |  |  | 8h |
| 173 | 7.6.4.2 | **Recover** | 2d | 2006-09-29 | 2006-10-02 |  | 2006-09-29 | 2006-10-02 | 2d | 45d |  |  | 8h |
| 174 | 7.6.4.2.1 | EE | 2d | 2006-09-29 | 2006-10-02 | 169FF | 2006-09-29 | 2006-10-02 | 2d | 45d |  |  | 8h |
| 175 | 7.7 | **Deployment contingency** | 2d | 2006-09-29 | 2006-10-02 |  | 2006-09-29 | 2006-10-02 | 2d | 45d |  |  | 296h |
| 176 | 7.7.1 | EE | 2d | 2006-09-29 | 2006-10-02 | 110SS | 2006-09-29 | 2006-10-02 | 2d | 45d |  | finish no earlier than 2006-10-02 | 48h |
| 177 | 7.7.2 | ME | 2d | 2006-09-29 | 2006-10-02 | 110SS | 2006-09-29 | 2006-10-02 | 2d | 45d |  | finish no earlier than 2006-10-02 | 64h |
| 178 | 7.7.3 | SE | 2d | 2006-09-29 | 2006-10-02 | 110SS | 2006-09-29 | 2006-10-02 | 2d | 45d |  | finish no earlier than 2006-10-02 | 120h |
| 179 | 7.7.4 | ME Tech | 2d | 2006-09-29 | 2006-10-02 | 110SS | 2006-09-29 | 2006-10-02 | 2d | 45d |  | finish no earlier than 2006-10-02 | 40h |
| 180 | 7.7.5 | EE Tech | 2d | 2006-09-29 | 2006-10-02 | 110SS | 2006-09-29 | 2006-10-02 | 2d | 45d |  | finish no earlier than 2006-10-02 | 24h |
| 182 | 8 | **Tech xfer** | 239d? | 2006-01-04 | 2006-12-04 |  | 2006-01-04 | 2006-01-04 | 1d? | 0d |  |  | 1040h |
| 183 | 8.1 | **Build 3 copies using exisiting design and spec, based on GiGi working** | 73d? | 2006-01-04 | 2006-04-14 |  | 2006-01-04 | 2006-01-04 | 1d? | 166d | 0d |  |  |
| 184 | 8.1.1 | Part invetory | 1d? | 2006-01-04 | 2006-01-04 |  | 2006-01-04 | 2006-01-04 | 1d? | 238d |  |  |  |
| 185 | 8.1.2 | Part storage/organize | 1d? | 2006-01-04 | 2006-01-04 |  | 2006-01-04 | 2006-01-04 | 1d? | 238d |  |  |  |
| 186 | 8.1.3 | Part ordering | 1d? | 2006-04-14 | 2006-04-14 |  | 2006-04-14 | 2006-04-14 | 1d? | 166d |  | finish no earlier than 2006-04-14 |  |
| 190 | 8.2 | **Copy Resources** | 1d? | 2006-01-04 | 2006-01-04 |  | 2006-01-04 | 2006-01-04 | 1d? | 238d |  |  | 760h |
| 191 | 8.2.1 | EE | 1d? | 2006-01-04 | 2006-01-04 | 183SS | 2006-01-04 | 2006-01-04 | 1d? | 238d |  |  | 160h |
| 192 | 8.2.2 | ME | 1d? | 2006-01-04 | 2006-01-04 | 183SS | 2006-01-04 | 2006-01-04 | 1d? | 238d |  |  | 40h |
| 193 | 8.2.3 | SE | 1d? | 2006-01-04 | 2006-01-04 | 183SS | 2006-01-04 | 2006-01-04 | 1d? | 238d |  |  | 40h |
| 194 | 8.2.4 | ME Tech | 1d? | 2006-01-04 | 2006-01-04 | 183SS | 2006-01-04 | 2006-01-04 | 1d? | 238d |  |  | 320h |
| 195 | 8.2.5 | EE Tech | 1d? | 2006-01-04 | 2006-01-04 | 183SS | 2006-01-04 | 2006-01-04 | 1d? | 238d |  |  | 160h |
| 196 | 8.2.6 | Shop | 1d? | 2006-01-04 | 2006-01-04 | 183SS | 2006-01-04 | 2006-01-04 | 1d? | 238d |  |  | 40h |
| 197 | 8.3 | initial user workshop - prep for demo deployments in 07; joint proposals | 1d? | 2006-01-04 | 2006-01-04 |  | 2006-01-04 | 2006-01-04 | 1d? | 238d |  |  |  |

| ID | WBS | Task | Duration | Start | Finish | Predecessors | Complete | Remaining | Baseline start | Baseline finish | Baseline duration | Total slack | Free slack | Constraint | Resources | Work |
| --- | --- | --- | --- | --- | --- | --- | --- | --- | --- | --- | --- | --- | --- | --- | --- | --- |
| 198 | 8.4 | **workshop Resources** | 1d? | 2006-12-04 | 2006-12-04 |  |  |  | 2006-12-04 | 2006-12-04 | 1d? | 0d |  |  |  | 280h |
| 199 | 8.4.1 | EE | 1d? | 2006-12-04 | 2006-12-04 | 197SS |  |  | 2006-12-04 | 2006-12-04 | 1d? | 0d |  | start no earlier than 2006-12-04 |  | 80h |
| 200 | 8.4.2 | ME | 1d? | 2006-12-04 | 2006-12-04 | 197SS |  |  | 2006-12-04 | 2006-12-04 | 1d? | 0d |  | start no earlier than 2006-12-04 |  | 80h |
| 201 | 8.4.3 | SE | 1d? | 2006-12-04 | 2006-12-04 | 197SS |  |  | 2006-12-04 | 2006-12-04 | 1d? | 0d |  | start no earlier than 2006-12-04 |  | 120h |
| 203 | 9 | **Deep water GiGI** | 67d? | 2006-01-04 A | 2006-04-06 |  | 1% | 66.53d? | 2006-01-04 | 2006-01-04 | 1d? | 172d |  |  |  | 880h |
| 204 | 9.1 | **D-ESP system testing** | 67d? | 2006-01-04 A | 2006-04-06 |  | 1% | 66.35d? | 2006-01-04 | 2006-01-04 | 1d? | 172d |  |  |  | 320h |
| 205 | 9.1.1 | 2G ESP valves and syringes in test fixture - 4C target | 1d? | 2006-01-04 A | 2006-01-04 |  | 75% | 0.25d? | 2006-01-04 | 2006-01-04 | 1d? | 238d |  |  |  |  |
| 206 | 9.1.2 | **DWSM Benchtop I&T** | 50d | 2006-01-04 | 2006-03-14 |  |  |  | 2006-01-04 | 2006-03-14 | 50d | 172d | 0d |  |  | 152h |
| 207 | 9.1.2.1 | EE | 6d | 2006-01-04 | 2006-01-11 |  |  |  | 2006-01-04 | 2006-01-11 | 6d | 216d |  |  | Scott [50%] | 24h |
| 208 | 9.1.2.2 | ME | 9d | 2006-01-04 | 2006-01-16 |  |  |  | 2006-01-04 | 2006-01-16 | 9d | 213d |  |  | Mark Brown [33.3%] | 24h |
| 209 | 9.1.2.3 | SE | 10d | 2006-03-01 | 2006-03-14 | 62 |  |  | 2006-03-01 | 2006-03-14 | 10d | 172d |  |  | Brent | 80h |
| 210 | 9.1.2.4 | Shop | 10d | 2006-01-04 | 2006-01-17 |  |  |  | 2006-01-04 | 2006-01-17 | 10d | 212d |  |  |  | 24h |
| 211 | 9.1.3 | **DWSM Coldroom testing** | 4d | 2006-03-15 | 2006-03-20 | 206 |  |  | 2006-03-15 | 2006-03-20 | 4d | 172d | 0d |  |  | 40h |
| 212 | 9.1.3.1 | EE | 4d | 2006-03-15 | 2006-03-20 |  |  |  | 2006-03-15 | 2006-03-20 | 4d | 172d |  |  | Scott [50%] | 16h |
| 213 | 9.1.3.2 | ME | 4d | 2006-03-15 | 2006-03-20 |  |  |  | 2006-03-15 | 2006-03-20 | 4d | 172d |  |  |  | 16h |
| 214 | 9.1.3.3 | SE | 2d | 2006-03-15 | 2006-03-16 |  |  |  | 2006-03-15 | 2006-03-16 | 2d | 174d |  |  | Brent [50%] | 8h |
| 215 | 9.1.4 | **DWSM ROV test** | 9d | 2006-03-21 | 2006-03-31 | 211 |  |  | 2006-03-21 | 2006-03-31 | 9d | 172d | 0d |  |  | 64h |
| 216 | 9.1.4.1 | EE | 9d | 2006-03-21 | 2006-03-31 |  |  |  | 2006-03-21 | 2006-03-31 | 9d | 172d |  |  | Scott [33.3%] | 24h |
| 217 | 9.1.4.2 | ME | 6d | 2006-03-21 | 2006-03-28 |  |  |  | 2006-03-21 | 2006-03-28 | 6d | 175d |  |  |  | 24h |
| 218 | 9.1.4.3 | SE | 4d | 2006-03-21 | 2006-03-24 |  |  |  | 2006-03-21 | 2006-03-24 | 4d | 177d |  |  | Brent [50%] | 16h |
| 219 | 9.1.5 | **D-ESP Benchtop I&T** | 1d? | 2006-04-03 | 2006-04-03 | 215 |  |  | 2006-04-03 | 2006-04-03 | 1d? | 172d | 0d |  |  | 16h |
| 220 | 9.1.5.1 | EE | 1d? | 2006-04-03 | 2006-04-03 |  |  |  | 2006-04-03 | 2006-04-03 | 1d? | 172d |  |  | Scott | 8h |
| 221 | 9.1.5.2 | ME | 1d? | 2006-04-03 | 2006-04-03 |  |  |  | 2006-04-03 | 2006-04-03 | 1d? | 172d |  |  |  |  |
| 222 | 9.1.5.3 | SE | 1d? | 2006-04-03 | 2006-04-03 |  |  |  | 2006-04-03 | 2006-04-03 | 1d? | 172d |  |  | Brent | 8h |

| ID | WBS | Task | Duration | Start | Finish | Predecessors | Baseline start | Baseline finish | Baseline duration | Total slack | Free slack | Resources | Work |
| --- | --- | --- | --- | --- | --- | --- | --- | --- | --- | --- | --- | --- | --- |
| 223 | 9.1.6 | **D-ESP Coldroom testing** | 1d? | 2006-04-04 | 2006-04-04 | 219 | 2006-04-04 | 2006-04-04 | 1d? | 172d | 0d |  | 16h |
| 224 | 9.1.6.1 | EE | 1d? | 2006-04-04 | 2006-04-04 |  | 2006-04-04 | 2006-04-04 | 1d? | 172d |  | Scott | 8h |
| 225 | 9.1.6.2 | ME | 1d? | 2006-04-04 | 2006-04-04 |  | 2006-04-04 | 2006-04-04 | 1d? | 172d |  |  |  |
| 226 | 9.1.6.3 | SE | 1d? | 2006-04-04 | 2006-04-04 |  | 2006-04-04 | 2006-04-04 | 1d? | 172d |  | Brent | 8h |
| 227 | 9.1.7 | **D-ESP Tank Test** | 1d? | 2006-04-05 | 2006-04-05 | 223 | 2006-04-05 | 2006-04-05 | 1d? | 172d | 0d |  | 16h |
| 228 | 9.1.7.1 | EE | 1d? | 2006-04-05 | 2006-04-05 |  | 2006-04-05 | 2006-04-05 | 1d? | 172d |  | Scott | 8h |
| 229 | 9.1.7.2 | ME | 1d? | 2006-04-05 | 2006-04-05 |  | 2006-04-05 | 2006-04-05 | 1d? | 172d |  |  |  |
| 230 | 9.1.7.3 | SE | 1d? | 2006-04-05 | 2006-04-05 |  | 2006-04-05 | 2006-04-05 | 1d? | 172d |  | Brent | 8h |
| 231 | 9.1.8 | **D-ESP ROV test** | 1d? | 2006-04-06 | 2006-04-06 | 227 | 2006-04-06 | 2006-04-06 | 1d? | 172d |  |  | 16h |
| 232 | 9.1.8.1 | EE | 1d? | 2006-04-06 | 2006-04-06 |  | 2006-04-06 | 2006-04-06 | 1d? | 172d |  | Scott | 8h |
| 233 | 9.1.8.2 | ME | 1d? | 2006-04-06 | 2006-04-06 |  | 2006-04-06 | 2006-04-06 | 1d? | 172d |  |  |  |
| 234 | 9.1.8.3 | SE | 1d? | 2006-04-06 | 2006-04-06 |  | 2006-04-06 | 2006-04-06 | 1d? | 172d |  | Brent | 8h |
| 235 | 9.2 | **Deploy D-ESP on ROV - 2, 1day dives (2mobs)** | 1d? | 2006-01-04 | 2006-01-04 |  | 2006-01-04 | 2006-01-04 | 1d? | 238d |  |  | 80h |
| 236 | 9.2.1 | **Deployment 1** | 1d? | 2006-01-04 | 2006-01-04 |  | 2006-01-04 | 2006-01-04 | 1d? | 238d |  |  | 40h |
| 237 | 9.2.1.1 | MOB | 1d? | 2006-01-04 | 2006-01-04 |  | 2006-01-04 | 2006-01-04 | 1d? | 238d |  |  |  |
| 238 | 9.2.1.2 | **MOB resources** | 1d? | 2006-01-04 | 2006-01-04 |  | 2006-01-04 | 2006-01-04 | 1d? | 238d |  |  | 24h |
| 239 | 9.2.1.2.1 | EE | 1d? | 2006-01-04 | 2006-01-04 |  | 2006-01-04 | 2006-01-04 | 1d? | 238d |  |  | 8h |
| 240 | 9.2.1.2.2 | ME | 1d? | 2006-01-04 | 2006-01-04 |  | 2006-01-04 | 2006-01-04 | 1d? | 238d |  |  | 8h |
| 241 | 9.2.1.2.3 | ME Tech | 1d? | 2006-01-04 | 2006-01-04 |  | 2006-01-04 | 2006-01-04 | 1d? | 238d |  |  | 8h |
| 242 | 9.2.1.3 | **Deployment** | 1d? | 2006-01-04 | 2006-01-04 |  | 2006-01-04 | 2006-01-04 | 1d? | 238d |  |  | 16h |
| 243 | 9.2.1.3.1 | EE | 1d? | 2006-01-04 | 2006-01-04 |  | 2006-01-04 | 2006-01-04 | 1d? | 238d |  |  | 8h |
| 244 | 9.2.1.3.2 | ME | 1d? | 2006-01-04 | 2006-01-04 |  | 2006-01-04 | 2006-01-04 | 1d? | 238d |  |  | 8h |
| 245 | 9.2.2 | **Deployment 2** | 1d? | 2006-01-04 | 2006-01-04 |  | 2006-01-04 | 2006-01-04 | 1d? | 238d |  |  | 40h |
| 246 | 9.2.2.1 | MOB | 1d? | 2006-01-04 | 2006-01-04 |  | 2006-01-04 | 2006-01-04 | 1d? | 238d |  |  |  |

| ID | WBS | Task | Duration | Start | Finish | Baseline start | Baseline finish | Baseline duration | Total slack | Work |
| --- | --- | --- | --- | --- | --- | --- | --- | --- | --- | --- |
| 247 | 9.2.2.2 | **MOB resources** | 1d? | 2006-01-04 | 2006-01-04 | 2006-01-04 | 2006-01-04 | 1d? | 238d | 24h |
| 248 | 9.2.2.2.1 | EE | 1d? | 2006-01-04 | 2006-01-04 | 2006-01-04 | 2006-01-04 | 1d? | 238d | 8h |
| 249 | 9.2.2.2.2 | ME | 1d? | 2006-01-04 | 2006-01-04 | 2006-01-04 | 2006-01-04 | 1d? | 238d | 8h |
| 250 | 9.2.2.2.3 | ME Tech | 1d? | 2006-01-04 | 2006-01-04 | 2006-01-04 | 2006-01-04 | 1d? | 238d | 8h |
| 251 | 9.2.2.3 | **Deployment** | 1d? | 2006-01-04 | 2006-01-04 | 2006-01-04 | 2006-01-04 | 1d? | 238d | 16h |
| 252 | 9.2.2.3.1 | EE | 1d? | 2006-01-04 | 2006-01-04 | 2006-01-04 | 2006-01-04 | 1d? | 238d | 8h |
| 253 | 9.2.2.3.2 | ME | 1d? | 2006-01-04 | 2006-01-04 | 2006-01-04 | 2006-01-04 | 1d? | 238d | 8h |
| 254 | 9.3 | **MARS interface** | 1d? | 2006-01-04 | 2006-01-04 | 2006-01-04 | 2006-01-04 | 1d? | 238d | 344h |
| 255 | 9.3.1 | **Power Supply and Communication** | 1d? | 2006-01-04 | 2006-01-04 | 2006-01-04 | 2006-01-04 | 1d? | 238d | 240h |
| 256 | 9.3.1.1 | EE | 1d? | 2006-01-04 | 2006-01-04 | 2006-01-04 | 2006-01-04 | 1d? | 238d | 160h |
| 257 | 9.3.1.2 | ME | 1d? | 2006-01-04 | 2006-01-04 | 2006-01-04 | 2006-01-04 | 1d? | 238d | 16h |
| 258 | 9.3.1.3 | SE | 1d? | 2006-01-04 | 2006-01-04 | 2006-01-04 | 2006-01-04 | 1d? | 238d | 24h |
| 259 | 9.3.1.4 | ME Tech | 1d? | 2006-01-04 | 2006-01-04 | 2006-01-04 | 2006-01-04 | 1d? | 238d | 40h |
| 260 | 9.3.2 | **deployment structure** | 1d? | 2006-01-04 | 2006-01-04 | 2006-01-04 | 2006-01-04 | 1d? | 238d | 104h |
| 261 | 9.3.2.1 | ME | 1d? | 2006-01-04 | 2006-01-04 | 2006-01-04 | 2006-01-04 | 1d? | 238d | 24h |
| 262 | 9.3.2.2 | ME Tech | 1d? | 2006-01-04 | 2006-01-04 | 2006-01-04 | 2006-01-04 | 1d? | 238d | 40h |
| 263 | 9.3.2.3 | Shop | 1d? | 2006-01-04 | 2006-01-04 | 2006-01-04 | 2006-01-04 | 1d? | 238d | 40h |
| 264 | 9.4 | **MARS deployment** | 1d? | 2006-01-04 | 2006-01-04 | 2006-01-04 | 2006-01-04 | 1d? | 238d | 136h |
| 265 | 9.4.1 | **MOB** | 1d? | 2006-01-04 | 2006-01-04 | 2006-01-04 | 2006-01-04 | 1d? | 238d | 72h |
| 266 | 9.4.1.1 | EE | 1d? | 2006-01-04 | 2006-01-04 | 2006-01-04 | 2006-01-04 | 1d? | 238d | 24h |
| 267 | 9.4.1.2 | ME | 1d? | 2006-01-04 | 2006-01-04 | 2006-01-04 | 2006-01-04 | 1d? | 238d | 8h |
| 268 | 9.4.1.3 | SE | 1d? | 2006-01-04 | 2006-01-04 | 2006-01-04 | 2006-01-04 | 1d? | 238d |  |
| 269 | 9.4.1.4 | ME Tech | 1d? | 2006-01-04 | 2006-01-04 | 2006-01-04 | 2006-01-04 | 1d? | 238d | 40h |
| 270 | 9.4.1.5 | EE Tech | 1d? | 2006-01-04 | 2006-01-04 | 2006-01-04 | 2006-01-04 | 1d? | 238d |  |
| 271 | 9.4.1.6 | Shop | 1d? | 2006-01-04 | 2006-01-04 | 2006-01-04 | 2006-01-04 | 1d? | 238d |  |

| ID | WBS | Task | Duration | Start | Finish | Baseline start | Baseline finish | Baseline duration | Total slack | Constraint | Work |
| --- | --- | --- | --- | --- | --- | --- | --- | --- | --- | --- | --- |
| 272 | 9.4.2 | **contingency/support** | 1d? | 2006-01-04 | 2006-01-04 | 2006-01-04 | 2006-01-04 | 1d? | 238d |  | 64h |
| 273 | 9.4.2.1 | EE | 1d? | 2006-01-04 | 2006-01-04 | 2006-01-04 | 2006-01-04 | 1d? | 238d |  | 8h |
| 274 | 9.4.2.2 | ME | 1d? | 2006-01-04 | 2006-01-04 | 2006-01-04 | 2006-01-04 | 1d? | 238d |  | 8h |
| 275 | 9.4.2.3 | SE | 1d? | 2006-01-04 | 2006-01-04 | 2006-01-04 | 2006-01-04 | 1d? | 238d |  | 24h |
| 276 | 9.4.2.4 | ME Tech | 1d? | 2006-01-04 | 2006-01-04 | 2006-01-04 | 2006-01-04 | 1d? | 238d |  | 24h |
| 277 | 9.4.2.5 | EE Tech | 1d? | 2006-01-04 | 2006-01-04 | 2006-01-04 | 2006-01-04 | 1d? | 238d |  |  |
| 278 | 9.4.2.6 | Shop | 1d? | 2006-01-04 | 2006-01-04 | 2006-01-04 | 2006-01-04 | 1d? | 238d |  |  |
| 280 | 10 | **NASA ASTEP** | 40d? | 2006-01-04 | 2006-02-28 | 2006-01-04 | 2006-01-04 | 1d? | 199d |  | 2480h |
| 281 | 10.1 | Meeting review | 1d? | 2006-02-24 | 2006-02-24 | 2006-02-24 | 2006-02-24 | 1d? | 201d | start no earlier than 2006-02-24 |  |
| 282 | 10.2 | Kick off meeting | 1d? | 2006-02-28 | 2006-02-28 | 2006-02-28 | 2006-02-28 | 1d? | 199d | start no earlier than 2006-02-28 |  |
| 283 | 10.3 | **system spec project start** | 1d? | 2006-01-04 | 2006-01-04 | 2006-01-04 | 2006-01-04 | 1d? | 238d |  | 280h |
| 284 | 10.3.1 | Sci | 1d? | 2006-01-04 | 2006-01-04 | 2006-01-04 | 2006-01-04 | 1d? | 238d |  |  |
| 285 | 10.3.2 | Sci Tech | 1d? | 2006-01-04 | 2006-01-04 | 2006-01-04 | 2006-01-04 | 1d? | 238d |  |  |
| 286 | 10.3.3 | EE | 1d? | 2006-01-04 | 2006-01-04 | 2006-01-04 | 2006-01-04 | 1d? | 238d |  | 80h |
| 287 | 10.3.4 | ME | 1d? | 2006-01-04 | 2006-01-04 | 2006-01-04 | 2006-01-04 | 1d? | 238d |  | 160h |
| 288 | 10.3.5 | SE | 1d? | 2006-01-04 | 2006-01-04 | 2006-01-04 | 2006-01-04 | 1d? | 238d |  | 40h |
| 289 | 10.4 | **analytical mod incorp (assumes LLNL subcontract funded - PCR)** | 1d? | 2006-01-04 | 2006-01-04 | 2006-01-04 | 2006-01-04 | 1d? | 238d |  | 360h |
| 290 | 10.4.1 | Sci | 1d? | 2006-01-04 | 2006-01-04 | 2006-01-04 | 2006-01-04 | 1d? | 238d |  |  |
| 291 | 10.4.2 | Sci Tech | 1d? | 2006-01-04 | 2006-01-04 | 2006-01-04 | 2006-01-04 | 1d? | 238d |  |  |
| 292 | 10.4.3 | EE | 1d? | 2006-01-04 | 2006-01-04 | 2006-01-04 | 2006-01-04 | 1d? | 238d |  | 80h |
| 293 | 10.4.4 | ME | 1d? | 2006-01-04 | 2006-01-04 | 2006-01-04 | 2006-01-04 | 1d? | 238d |  | 80h |
| 294 | 10.4.5 | SE | 1d? | 2006-01-04 | 2006-01-04 | 2006-01-04 | 2006-01-04 | 1d? | 238d |  | 200h |
| 295 | 10.5 | **ISUS context sensor incorp** | 1d? | 2006-01-04 | 2006-01-04 | 2006-01-04 | 2006-01-04 | 1d? | 238d |  | 120h |
| 296 | 10.5.1 | Sci | 1d? | 2006-01-04 | 2006-01-04 | 2006-01-04 | 2006-01-04 | 1d? | 238d |  |  |
| 297 | 10.5.2 | Sci Tech | 1d? | 2006-01-04 | 2006-01-04 | 2006-01-04 | 2006-01-04 | 1d? | 238d |  |  |
| 298 | 10.5.3 | EE | 1d? | 2006-01-04 | 2006-01-04 | 2006-01-04 | 2006-01-04 | 1d? | 238d |  | 16h |
| 299 | 10.5.4 | ME | 1d? | 2006-01-04 | 2006-01-04 | 2006-01-04 | 2006-01-04 | 1d? | 238d |  | 24h |
| 300 | 10.5.5 | SE | 1d? | 2006-01-04 | 2006-01-04 | 2006-01-04 | 2006-01-04 | 1d? | 238d |  | 80h |

| ID | WBS | Task | Duration | Start | Finish | Baseline start | Baseline finish | Baseline duration | Total slack | Work |
| --- | --- | --- | --- | --- | --- | --- | --- | --- | --- | --- |
| 301 | 10.6 | **modify/fab DWSM** | 1d? | 2006-01-04 | 2006-01-04 | 2006-01-04 | 2006-01-04 | 1d? | 238d | 440h |
| 302 | 10.6.1 | Sci | 1d? | 2006-01-04 | 2006-01-04 | 2006-01-04 | 2006-01-04 | 1d? | 238d |  |
| 303 | 10.6.2 | Sci Tech | 1d? | 2006-01-04 | 2006-01-04 | 2006-01-04 | 2006-01-04 | 1d? | 238d |  |
| 304 | 10.6.3 | EE | 1d? | 2006-01-04 | 2006-01-04 | 2006-01-04 | 2006-01-04 | 1d? | 238d | 160h |
| 305 | 10.6.4 | ME | 1d? | 2006-01-04 | 2006-01-04 | 2006-01-04 | 2006-01-04 | 1d? | 238d | 80h |
| 306 | 10.6.5 | SE | 1d? | 2006-01-04 | 2006-01-04 | 2006-01-04 | 2006-01-04 | 1d? | 238d | 40h |
| 307 | 10.6.6 | ME Tech | 1d? | 2006-01-04 | 2006-01-04 | 2006-01-04 | 2006-01-04 | 1d? | 238d | 80h |
| 308 | 10.6.7 | Shop | 1d? | 2006-01-04 | 2006-01-04 | 2006-01-04 | 2006-01-04 | 1d? | 238d | 80h |
| 309 | 10.7 | **Modify/fab 2G** | 1d? | 2006-01-04 | 2006-01-04 | 2006-01-04 | 2006-01-04 | 1d? | 238d | 720h |
| 310 | 10.7.1 | Sci | 1d? | 2006-01-04 | 2006-01-04 | 2006-01-04 | 2006-01-04 | 1d? | 238d |  |
| 311 | 10.7.2 | Sci Tech | 1d? | 2006-01-04 | 2006-01-04 | 2006-01-04 | 2006-01-04 | 1d? | 238d |  |
| 312 | 10.7.3 | EE | 1d? | 2006-01-04 | 2006-01-04 | 2006-01-04 | 2006-01-04 | 1d? | 238d | 160h |
| 313 | 10.7.4 | ME | 1d? | 2006-01-04 | 2006-01-04 | 2006-01-04 | 2006-01-04 | 1d? | 238d | 80h |
| 314 | 10.7.5 | SE | 1d? | 2006-01-04 | 2006-01-04 | 2006-01-04 | 2006-01-04 | 1d? | 238d | 80h |
| 315 | 10.7.6 | ME Tech | 1d? | 2006-01-04 | 2006-01-04 | 2006-01-04 | 2006-01-04 | 1d? | 238d | 160h |
| 316 | 10.7.7 | EE Tech | 1d? | 2006-01-04 | 2006-01-04 | 2006-01-04 | 2006-01-04 | 1d? | 238d | 80h |
| 317 | 10.7.8 | Shop | 1d? | 2006-01-04 | 2006-01-04 | 2006-01-04 | 2006-01-04 | 1d? | 238d | 160h |
| 318 | 10.8 | **design/fab pressure housing** | 1d? | 2006-01-04 | 2006-01-04 | 2006-01-04 | 2006-01-04 | 1d? | 238d | 320h |
| 319 | 10.8.1 | Sci | 1d? | 2006-01-04 | 2006-01-04 | 2006-01-04 | 2006-01-04 | 1d? | 238d |  |
| 320 | 10.8.2 | Sci Tech | 1d? | 2006-01-04 | 2006-01-04 | 2006-01-04 | 2006-01-04 | 1d? | 238d |  |
| 321 | 10.8.3 | EE | 1d? | 2006-01-04 | 2006-01-04 | 2006-01-04 | 2006-01-04 | 1d? | 238d | 40h |
| 322 | 10.8.4 | ME | 1d? | 2006-01-04 | 2006-01-04 | 2006-01-04 | 2006-01-04 | 1d? | 238d | 80h |
| 323 | 10.8.5 | ME Tech | 1d? | 2006-01-04 | 2006-01-04 | 2006-01-04 | 2006-01-04 | 1d? | 238d | 80h |
| 324 | 10.8.6 | EE Tech | 1d? | 2006-01-04 | 2006-01-04 | 2006-01-04 | 2006-01-04 | 1d? | 238d | 40h |
| 325 | 10.8.7 | Shop | 1d? | 2006-01-04 | 2006-01-04 | 2006-01-04 | 2006-01-04 | 1d? | 238d | 80h |

| ID | WBS | Task | Duration | Start | Finish | Baseline start | Baseline finish | Baseline duration | Total slack | Work |
| --- | --- | --- | --- | --- | --- | --- | --- | --- | --- | --- |
| 326 | 10.9 | **design/fab benthic mooring structure** | 1d? | 2006-01-04 | 2006-01-04 | 2006-01-04 | 2006-01-04 | 1d? | 238d | 240h |
| 327 | 10.9.1 | Sci | 1d? | 2006-01-04 | 2006-01-04 | 2006-01-04 | 2006-01-04 | 1d? | 238d |  |
| 328 | 10.9.2 | Sci Tech | 1d? | 2006-01-04 | 2006-01-04 | 2006-01-04 | 2006-01-04 | 1d? | 238d |  |
| 329 | 10.9.3 | EE | 1d? | 2006-01-04 | 2006-01-04 | 2006-01-04 | 2006-01-04 | 1d? | 238d | 40h |
| 330 | 10.9.4 | ME | 1d? | 2006-01-04 | 2006-01-04 | 2006-01-04 | 2006-01-04 | 1d? | 238d | 40h |
| 331 | 10.9.5 | ME Tech | 1d? | 2006-01-04 | 2006-01-04 | 2006-01-04 | 2006-01-04 | 1d? | 238d | 80h |
| 332 | 10.9.6 | EE Tech | 1d? | 2006-01-04 | 2006-01-04 | 2006-01-04 | 2006-01-04 | 1d? | 238d | 40h |
| 333 | 10.9.7 | Shop | 1d? | 2006-01-04 | 2006-01-04 | 2006-01-04 | 2006-01-04 | 1d? | 238d | 40h |
| 334 | 10.10 | **Santa Monica Basin cruise?** | 1d? | 2006-01-04 | 2006-01-04 | 2006-01-04 | 2006-01-04 | 1d? | 238d |  |
| 335 | 10.10.1 | Sci | 1d? | 2006-01-04 | 2006-01-04 | 2006-01-04 | 2006-01-04 | 1d? | 238d |  |
| 336 | 10.10.2 | Sci Tech | 1d? | 2006-01-04 | 2006-01-04 | 2006-01-04 | 2006-01-04 | 1d? | 238d |  |
| 337 | 10.10.3 | EE | 1d? | 2006-01-04 | 2006-01-04 | 2006-01-04 | 2006-01-04 | 1d? | 238d |  |
| 338 | 10.10.4 | ME | 1d? | 2006-01-04 | 2006-01-04 | 2006-01-04 | 2006-01-04 | 1d? | 238d |  |
| 339 | 10.10.5 | SE | 1d? | 2006-01-04 | 2006-01-04 | 2006-01-04 | 2006-01-04 | 1d? | 238d |  |
| 340 | 10.10.6 | ME Tech | 1d? | 2006-01-04 | 2006-01-04 | 2006-01-04 | 2006-01-04 | 1d? | 238d |  |
| 341 | 10.10.7 | EE Tech | 1d? | 2006-01-04 | 2006-01-04 | 2006-01-04 | 2006-01-04 | 1d? | 238d |  |
| 342 | 10.10.8 | Shop | 1d? | 2006-01-04 | 2006-01-04 | 2006-01-04 | 2006-01-04 | 1d? | 238d |  |
| 344 | 11 | **Moore Foundation** | 1d? | 2006-01-04 | 2006-01-04 | 2006-01-04 | 2006-01-04 | 1d? | 238d | 1360h |
| 345 | 11.1 | **define functional requirements (w/ Zehr) - system concept devel** | 1d? | 2006-01-04 | 2006-01-04 | 2006-01-04 | 2006-01-04 | 1d? | 238d | 152h |
| 346 | 11.1.1 | Sci | 1d? | 2006-01-04 | 2006-01-04 | 2006-01-04 | 2006-01-04 | 1d? | 238d |  |
| 347 | 11.1.2 | EE | 1d? | 2006-01-04 | 2006-01-04 | 2006-01-04 | 2006-01-04 | 1d? | 238d | 40h |
| 348 | 11.1.3 | ME | 1d? | 2006-01-04 | 2006-01-04 | 2006-01-04 | 2006-01-04 | 1d? | 238d | 80h |
| 349 | 11.1.4 | SE | 1d? | 2006-01-04 | 2006-01-04 | 2006-01-04 | 2006-01-04 | 1d? | 238d | 32h |
| 350 | 11.2 | **evaluate existing analytical modules - candidacy** | 1d? | 2006-01-04 | 2006-01-04 | 2006-01-04 | 2006-01-04 | 1d? | 238d | 224h |
| 351 | 11.2.1 | Sci | 1d? | 2006-01-04 | 2006-01-04 | 2006-01-04 | 2006-01-04 | 1d? | 238d |  |
| 352 | 11.2.2 | EE | 1d? | 2006-01-04 | 2006-01-04 | 2006-01-04 | 2006-01-04 | 1d? | 238d | 80h |
| 353 | 11.2.3 | ME | 1d? | 2006-01-04 | 2006-01-04 | 2006-01-04 | 2006-01-04 | 1d? | 238d | 120h |
| 354 | 11.2.4 | SE | 1d? | 2006-01-04 | 2006-01-04 | 2006-01-04 | 2006-01-04 | 1d? | 238d | 24h |

| ID | WBS | Task | Duration | Start | Finish | Baseline start | Baseline finish | Baseline duration | Total slack | Work |
| --- | --- | --- | --- | --- | --- | --- | --- | --- | --- | --- |
| 355 | 11.3 | **downselect candidate modules - develop test plan** | 1d? | 2006-01-04 | 2006-01-04 | 2006-01-04 | 2006-01-04 | 1d? | 238d | 88h |
| 356 | 11.3.1 | Sci | 1d? | 2006-01-04 | 2006-01-04 | 2006-01-04 | 2006-01-04 | 1d? | 238d |  |
| 357 | 11.3.2 | EE | 1d? | 2006-01-04 | 2006-01-04 | 2006-01-04 | 2006-01-04 | 1d? | 238d | 24h |
| 358 | 11.3.3 | ME | 1d? | 2006-01-04 | 2006-01-04 | 2006-01-04 | 2006-01-04 | 1d? | 238d | 40h |
| 359 | 11.3.4 | SE | 1d? | 2006-01-04 | 2006-01-04 | 2006-01-04 | 2006-01-04 | 1d? | 238d | 24h |
| 360 | 11.4 | **develop lab test fixture that incorps elements of ESP and analytical modules** | 1d? | 2006-01-04 | 2006-01-04 | 2006-01-04 | 2006-01-04 | 1d? | 238d | 896h |
| 361 | 11.4.1 | Sci | 1d? | 2006-01-04 | 2006-01-04 | 2006-01-04 | 2006-01-04 | 1d? | 238d |  |
| 362 | 11.4.2 | EE | 1d? | 2006-01-04 | 2006-01-04 | 2006-01-04 | 2006-01-04 | 1d? | 238d | 176h |
| 363 | 11.4.3 | ME | 1d? | 2006-01-04 | 2006-01-04 | 2006-01-04 | 2006-01-04 | 1d? | 238d | 240h |
| 364 | 11.4.4 | SE | 1d? | 2006-01-04 | 2006-01-04 | 2006-01-04 | 2006-01-04 | 1d? | 238d | 80h |
| 365 | 11.4.5 | ME Tech | 1d? | 2006-01-04 | 2006-01-04 | 2006-01-04 | 2006-01-04 | 1d? | 238d | 160h |
| 366 | 11.4.6 | EE Tech | 1d? | 2006-01-04 | 2006-01-04 | 2006-01-04 | 2006-01-04 | 1d? | 238d | 80h |
| 367 | 11.4.7 | Shop | 1d? | 2006-01-04 | 2006-01-04 | 2006-01-04 | 2006-01-04 | 1d? | 238d | 160h |
